# Meridian Gas Processing Plant — Phase 2 Expansion

Schedule from Primavera P6, 2024-01-08 to 2027-04-30, data date 2025-10-01.

## Schedule

| ID | Activity | Duration | Start | Finish | Predecessors | Complete |
| --- | --- | --- | --- | --- | --- | --- |
|  | **Civil & Structural** |  | 2024-11-04 | 2026-03-06 |  |  |
|  | **Site Prep & Enabling Works** |  | 2024-11-04 | 2025-03-28 |  |  |
| A3920 | Site mobilization & temporary facilities | 19d | 2024-11-04 | 2024-12-01 | A1550 SS+69d, A3220 SS, A2860 SS, A2400 SS | 100% |
| A3930 | Haul roads & laydown areas | 24d | 2024-11-13 | 2024-12-17 | A3920 SS+8d | 100% |
| A3940 | Construction power & water | 24d | 2024-11-18 | 2024-12-21 | A3930 SS+3d, A1540 SS, A2410 SS | 100% |
| A3950 | Bulk earthworks & grading | 19d | 2024-11-21 | 2024-12-18 | A3940 SS+3d | 100% |
| A3960 | Site drainage & culverts | 25d | 2024-11-22 | 2024-12-28 | A3950 SS+8d | 100% |
| A3970 | Fencing & security | 18d | 2024-11-30 | 2024-12-25 | A3960 SS+4d, A2010 SS, A3950 SS | 100% |
| A3980 | Site mobilization & temporary facilities — U-21 Inlet & Metering | 26d | 2024-12-01 | 2025-01-06 | A3970 SS+8d, A1770 SS, A2010 SS | 100% |
| A3990 | Haul roads & laydown areas — U-21 Inlet & Metering | 23d | 2024-12-05 | 2025-01-07 | A3980 SS+4d | 100% |
| A4000 | Construction power & water — U-21 Inlet & Metering | 16d | 2024-12-08 | 2024-12-30 | A3990 SS+4d, A2890 SS | 100% |
| A4010 | Bulk earthworks & grading — U-21 Inlet & Metering | 18d | 2024-12-15 | 2025-01-08 | A4000 SS+4d | 100% |
| A4020 | Site drainage & culverts — U-21 Inlet & Metering | 15d | 2024-12-18 | 2025-01-08 | A4010 SS+7d, A2900 SS | 100% |
| A4040 | Site mobilization & temporary facilities — U-22 Compression | 13d | 2024-12-29 | 2025-01-15 | A4030 SS+7d | 100% |
| A4030 | Fencing & security — U-21 Inlet & Metering | 11d | 2024-12-30 | 2025-01-14 | A4020 SS+4d, A1810 SS, A1800 SS | 100% |
| A4050 | Haul roads & laydown areas — U-22 Compression | 17d | 2025-01-03 | 2025-01-28 | A4040 SS+4d | 100% |
| A4060 | Construction power & water — U-22 Compression | 27d | 2025-01-08 | 2025-02-15 | A4050 SS+6d, A3260 SS | 100% |
| A4070 | Bulk earthworks & grading — U-22 Compression | 13d | 2025-01-14 | 2025-02-01 | A4060 SS+3d | 100% |
| A4080 | Site drainage & culverts — U-22 Compression | 12d | 2025-01-17 | 2025-02-04 | A4070 SS+3d | 100% |
| A4090 | Fencing & security — U-22 Compression | 13d | 2025-01-25 | 2025-02-12 | A4080 SS+10d, A3270 SS, A1840 SS | 100% |
| A4100 | Site mobilization & temporary facilities — U-23 Dehydration | 21d | 2025-01-26 | 2025-02-24 | A4090 SS+3d | 100% |
| A4110 | Haul roads & laydown areas — U-23 Dehydration | 15d | 2025-02-01 | 2025-02-21 | A4100 SS+5d | 100% |
| A4120 | Construction power & water — U-23 Dehydration | 11d | 2025-02-06 | 2025-02-22 | A4110 SS+8d | 100% |
| A4130 | Bulk earthworks & grading — U-23 Dehydration | 14d | 2025-02-14 | 2025-03-06 | A4120 SS+5d | 100% |
| A4140 | Site drainage & culverts — U-23 Dehydration | 20d | 2025-02-21 | 2025-03-21 | A4130 SS+4d | 100% |
| A4150 | Fencing & security — U-23 Dehydration | 10d | 2025-02-21 | 2025-03-09 | A4140 SS+8d, A3490 SS, A4230 SS | 100% |
| A4160 | Site mobilization & temporary facilities — U-24 Fractionation | 25d | 2025-02-21 | 2025-03-28 | A4150 SS+10d | 100% |
| A4170 | Haul roads & laydown areas — U-24 Fractionation | 17d | 2025-03-05 | 2025-03-28 | A4160 SS+8d | 100% |

| ID | Activity | Duration | Start | Finish | Predecessors | Complete |
| --- | --- | --- | --- | --- | --- | --- |
|  | **Foundations & Piling** |  | 2025-02-03 | 2025-09-12 |  |  |
| A4180 | Piling | 14d | 2025-02-03 | 2025-02-22 | A1590, A3920 SS+72d, A4110 SS, A2080 SS | 100% |
| A4190 | Pile caps & grade beams | 25d | 2025-02-10 | 2025-03-17 | A4180 SS+3d | 100% |
| A4200 | Foundations — static equipment | 13d | 2025-02-10 | 2025-02-27 | A4190 SS+6d, A4120 SS, A3280 SS | 100% |
| A4210 | Foundations — rotating equipment | 14d | 2025-02-17 | 2025-03-09 | A4200 SS+3d, A1880 SS | 100% |
| A4220 | Pedestals & plinths | 26d | 2025-02-19 | 2025-03-27 | A4210 SS+10d, A4130 SS, A3480 SS | 100% |
| A4230 | Underground piping & services | 13d | 2025-02-19 | 2025-03-10 | A4220 SS+4d | 100% |
| A4240 | Duct banks & earthing grid | 13d | 2025-02-21 | 2025-03-12 | A4230 SS+3d, A3490 SS | 100% |
| A4250 | Piling — U-21 Inlet & Metering | 19d | 2025-03-03 | 2025-03-29 | A4240 SS+4d | 100% |
| A4270 | Foundations — static equipment — U-21 Inlet & Metering | 28d | 2025-03-04 | 2025-04-11 | A4260 SS+7d, A3500 SS, A2980 SS | 100% |
| A4260 | Pile caps & grade beams — U-21 Inlet & Metering | 16d | 2025-03-06 | 2025-03-29 | A4250 SS+10d | 100% |
| A4280 | Foundations — rotating equipment — U-21 Inlet & Metering | 15d | 2025-03-15 | 2025-04-05 | A4270 SS+5d, A2510 SS, A4260 SS | 100% |
| A4290 | Pedestals & plinths — U-21 Inlet & Metering | 14d | 2025-03-17 | 2025-04-05 | A4280 SS+9d, A2990 SS, A2510 SS | 100% |
| A4300 | Underground piping & services — U-21 Inlet & Metering | 15d | 2025-03-20 | 2025-04-10 | A4290 SS+5d, A2130 SS, A3530 SS | 100% |
| A4310 | Duct banks & earthing grid — U-21 Inlet & Metering | 19d | 2025-03-24 | 2025-04-20 | A4300 SS+3d | 100% |
| A4330 | Pile caps & grade beams — U-22 Compression | 20d | 2025-03-26 | 2025-04-23 | A4320 SS+3d | 100% |
| A4340 | Foundations — static equipment — U-22 Compression | 17d | 2025-03-28 | 2025-04-22 | A4330 SS+3d, A4310 SS, A3000 SS | 100% |
| A4320 | Piling — U-22 Compression | 24d | 2025-03-29 | 2025-05-01 | A4310 SS+3d | 100% |
| A4350 | Foundations — rotating equipment — U-22 Compression | 20d | 2025-04-03 | 2025-05-01 | A4340 SS+9d | 100% |
| A4360 | Pedestals & plinths — U-22 Compression | 21d | 2025-04-08 | 2025-05-07 | A4350 SS+5d | 100% |
| A4370 | Underground piping & services — U-22 Compression | 16d | 2025-04-13 | 2025-05-05 | A4360 SS+6d, A2540 SS | 100% |
| A4380 | Duct banks & earthing grid — U-22 Compression | 19d | 2025-04-16 | 2025-05-13 | A4370 SS+5d, A2160 SS, A2540 SS | 100% |
| A4390 | Piling — U-23 Dehydration | 19d | 2025-04-17 | 2025-05-14 | A4380 SS+10d | 100% |
| A4400 | Pile caps & grade beams — U-23 Dehydration | 15d | 2025-04-24 | 2025-05-15 | A4390 SS+7d, A3580 SS | 100% |
| A4410 | Foundations — static equipment — U-23 Dehydration | 15d | 2025-04-27 | 2025-05-16 | A4400 SS+3d, A2550 SS, A3580 SS | 100% |
| A4420 | Foundations — rotating equipment — U-23 Dehydration | 13d | 2025-05-02 | 2025-05-21 | A4410 SS+5d, A2180 SS, A2170 SS | 100% |
| A4430 | Pedestals & plinths — U-23 Dehydration | 12d | 2025-05-04 | 2025-05-20 | A4420 SS+10d | 100% |
| A4440 | Underground piping & services — U-23 Dehydration | 17d | 2025-05-05 | 2025-05-28 | A4430 SS+7d, A3600 SS, A2180 SS | 100% |
| A4470 | Pile caps & grade beams — U-24 Fractionation | 22d | 2025-05-14 | 2025-06-13 | A4460 SS+3d, A2560 SS, A3050 SS | 100% |
| A4450 | Duct banks & earthing grid — U-23 Dehydration | 22d | 2025-05-15 | 2025-06-16 | A4440 SS+8d | 100% |
| A4460 | Piling — U-24 Fractionation | 10d | 2025-05-17 | 2025-06-01 | A4450 SS+4d, A3610 SS, A2560 SS | 100% |
| A4480 | Foundations — static equipment — U-24 Fractionation | 13d | 2025-05-20 | 2025-06-07 | A4470 SS+10d, A2570 SS, A4450 SS | 100% |
| A4490 | Foundations — rotating equipment — U-24 Fractionation | 22d | 2025-05-21 | 2025-06-22 | A4480 SS+8d | 100% |
| A4500 | Pedestals & plinths — U-24 Fractionation | 21d | 2025-05-30 | 2025-06-30 | A4490 SS+8d | 100% |
| A4510 | Underground piping & services — U-24 Fractionation | 16d | 2025-06-02 | 2025-06-24 | A4500 SS+6d, A4490 SS | 100% |
| A4520 | Duct banks & earthing grid — U-24 Fractionation | 19d | 2025-06-02 | 2025-06-29 | A4510 SS+3d | 100% |
| A4530 | Piling — U-25 Utilities | 14d | 2025-06-07 | 2025-06-26 | A4520 SS+4d, A3070 SS | 100% |
| A4540 | Pile caps & grade beams — U-25 Utilities | 11d | 2025-06-13 | 2025-06-30 | A4530 SS+9d, A3360 SS, A4750 SS | 100% |
| A4560 | Foundations — rotating equipment — U-25 Utilities | 17d | 2025-06-19 | 2025-07-14 | A4550 SS+9d | 100% |
| A4550 | Foundations — static equipment — U-25 Utilities | 18d | 2025-06-20 | 2025-07-16 | A4540 SS+10d, A4790 SS, A3080 SS | 100% |
| A4580 | Underground piping & services — U-25 Utilities | 17d | 2025-06-24 | 2025-07-17 | A4570 SS+6d | 100% |
| A4590 | Duct banks & earthing grid — U-25 Utilities | 23d | 2025-06-26 | 2025-07-29 | A4580 SS+4d, A2240 SS | 100% |
| A4570 | Pedestals & plinths — U-25 Utilities | 20d | 2025-06-27 | 2025-07-26 | A4560 SS+9d, A3680 SS | 100% |
| A4600 | Piling — U-26 Offsites & Flare | 20d | 2025-07-04 | 2025-08-03 | A4590 SS+7d | 100% |
| A4610 | Pile caps & grade beams — U-26 Offsites & Flare | 25d | 2025-07-06 | 2025-08-08 | A4600 SS+4d, A2350 | 100% |
| A4630 | Foundations — rotating equipment — U-26 Offsites & Flare | 17d | 2025-07-12 | 2025-08-05 | A4620 SS+9d | 100% |
| A4620 | Foundations — static equipment — U-26 Offsites & Flare | 19d | 2025-07-14 | 2025-08-09 | A4610 SS+4d | 100% |
| A4640 | Pedestals & plinths — U-26 Offsites & Flare | 17d | 2025-07-17 | 2025-08-11 | A4630 SS+7d, A4620 SS, A2610 SS | 100% |
| A4650 | Underground piping & services — U-26 Offsites & Flare | 11d | 2025-07-24 | 2025-08-09 | A4640 SS+10d | 100% |
| A4660 | Duct banks & earthing grid — U-26 Offsites & Flare | 18d | 2025-07-26 | 2025-08-20 | A4650 SS+4d, A2620 SS | 100% |
| A4670 | Piling — batch 7 | 13d | 2025-08-02 | 2025-08-20 | A4660 SS+8d | 100% |
| A4680 | Pile caps & grade beams — batch 7 | 14d | 2025-08-04 | 2025-08-22 | A4670 SS+6d | 100% |
| A4700 | Foundations — rotating equipment — batch 7 | 17d | 2025-08-05 | 2025-08-28 | A4690 SS+8d, A2280 SS, A4670 SS | 100% |
| A4690 | Foundations — static equipment — batch 7 | 22d | 2025-08-06 | 2025-09-06 | A4680 SS+3d, A2280 SS | 100% |
| A4710 | Pedestals & plinths — batch 7 | 23d | 2025-08-08 | 2025-09-10 | A4700 SS+9d, A4900 SS, A4680 SS | 100% |
| A4720 | Underground piping & services — batch 7 | 25d | 2025-08-09 | 2025-09-12 | A4710 SS+6d | 100% |
| A4730 | Duct banks & earthing grid — batch 7 | 21d | 2025-08-14 | 2025-09-12 | A4720 SS+6d | 100% |

| ID | Activity | Duration | Start | Finish | Predecessors | Complete | Remaining |
| --- | --- | --- | --- | --- | --- | --- | --- |
|  | **Structural Steelwork Erection** |  | 2025-06-02 | 2026-03-06 |  |  |  |
| A4740 | Main steel erection | 14d | 2025-06-02 | 2025-06-20 | A4180 SS+107d, A2210 SS, A4500 SS | 100% |  |
| A4750 | Secondary steel & bracing | 26d | 2025-06-04 | 2025-07-10 | A4740 SS+5d | 100% |  |
| A4770 | Platforms, stairs & ladders | 18d | 2025-06-09 | 2025-07-03 | A4760 SS+8d, A4750 SS, A3070 SS | 100% |  |
| A4760 | Pipe-rack erection | 23d | 2025-06-13 | 2025-07-16 | A4750 SS+7d | 100% |  |
| A4780 | Fireproofing | 14d | 2025-06-14 | 2025-07-03 | A4770 SS+9d | 100% |  |
| A4790 | Survey & alignment checks | 18d | 2025-06-17 | 2025-07-13 | A4780 SS+7d | 100% |  |
| A4800 | Punch & handover to mechanical | 23d | 2025-06-22 | 2025-07-23 | A4790 SS+3d | 100% |  |
| A4810 | Main steel erection — U-21 Inlet & Metering | 19d | 2025-06-26 | 2025-07-23 | A4800 SS+7d | 100% |  |
| A4820 | Secondary steel & bracing — U-21 Inlet & Metering | 25d | 2025-06-28 | 2025-08-03 | A4810 SS+6d, A3680 SS | 100% |  |
| A4830 | Pipe-rack erection — U-21 Inlet & Metering | 15d | 2025-07-08 | 2025-07-29 | A4820 SS+9d | 100% |  |
| A4840 | Platforms, stairs & ladders — U-21 Inlet & Metering | 16d | 2025-07-08 | 2025-07-30 | A4830 SS+7d, A3100 SS | 100% |  |
| A4860 | Survey & alignment checks — U-21 Inlet & Metering | 13d | 2025-07-15 | 2025-08-03 | A4850 SS+8d | 100% |  |
| A4850 | Fireproofing — U-21 Inlet & Metering | 16d | 2025-07-17 | 2025-08-09 | A4840 SS+10d | 100% |  |
| A4870 | Punch & handover to mechanical — U-21 Inlet & Metering | 16d | 2025-07-17 | 2025-08-09 | A4860 SS+5d, A4620 SS | 100% |  |
| A4880 | Main steel erection — U-22 Compression | 22d | 2025-07-24 | 2025-08-25 | A4870 SS+8d, A2620 SS, A4850 SS | 100% |  |
| A4890 | Secondary steel & bracing — U-22 Compression | 23d | 2025-07-25 | 2025-08-27 | A4880 SS+9d | 100% |  |
| A4900 | Pipe-rack erection — U-22 Compression | 13d | 2025-08-05 | 2025-08-24 | A4890 SS+6d | 100% |  |
| A4910 | Platforms, stairs & ladders — U-22 Compression | 26d | 2025-08-07 | 2025-09-14 | A4900 SS+8d | 100% |  |
| A4930 | Survey & alignment checks — U-22 Compression | 19d | 2025-08-09 | 2025-09-04 | A4920 SS+6d, A4910 SS | 100% |  |
| A4920 | Fireproofing — U-22 Compression | 22d | 2025-08-12 | 2025-09-11 | A4910 SS+4d | 100% |  |
| A4940 | Punch & handover to mechanical — U-22 Compression | 12d | 2025-08-13 | 2025-08-31 | A4930 SS+7d, A4720 SS, A3130 SS | 100% |  |
| A4950 | Main steel erection — U-23 Dehydration | 12d | 2025-08-19 | 2025-09-04 | A4940 SS+8d | 100% |  |
| A4960 | Secondary steel & bracing — U-23 Dehydration | 15d | 2025-08-22 | 2025-09-12 | A4950 SS+10d, A2290 SS, A3410 SS | 100% |  |
| A4970 | Pipe-rack erection — U-23 Dehydration | 13d | 2025-08-26 | 2025-09-13 | A4960 SS+6d, A2650 SS, A4950 SS | 100% |  |
| A4980 | Platforms, stairs & ladders — U-23 Dehydration | 17d | 2025-09-03 | 2025-09-28 | A4970 SS+5d, A5420 SS, A2300 SS | 100% |  |
| A4990 | Fireproofing — U-23 Dehydration | 24d | 2025-09-08 | 2025-10-12 | A4980 SS+10d |  | 24d |
| A5010 | Punch & handover to mechanical — U-23 Dehydration | 14d | 2025-09-08 | 2025-09-28 | A5000 SS+9d, A5430 SS, A5880 SS | 100% |  |
| A5000 | Survey & alignment checks — U-23 Dehydration | 13d | 2025-09-11 | 2025-09-30 | A4990 SS+8d, A5430 SS | 100% |  |
| A5020 | Main steel erection — U-24 Fractionation | 21d | 2025-09-19 | 2025-10-20 | A5010 SS+4d |  | 21d |
| A5030 | Secondary steel & bracing — U-24 Fractionation | 14d | 2025-09-20 | 2025-10-09 | A5020 SS+7d |  | 14d |
| A5040 | Pipe-rack erection — U-24 Fractionation | 26d | 2025-09-20 | 2025-10-27 | A5030 SS+7d, A5020 SS, A5460 SS |  | 26d |
| A5050 | Platforms, stairs & ladders — U-24 Fractionation | 28d | 2025-09-30 | 2025-11-07 | A5040 SS+8d |  | 28d |
| A5060 | Fireproofing — U-24 Fractionation | 12d | 2025-10-04 | 2025-10-21 | A5050 SS+9d |  |  |
| A5070 | Survey & alignment checks — U-24 Fractionation | 14d | 2025-10-04 | 2025-10-23 | A5060 SS+8d, A3820 SS, A5050 SS |  |  |
| A5090 | Main steel erection — U-25 Utilities | 19d | 2025-10-11 | 2025-11-06 | A5080 SS+7d |  |  |
| A5080 | Punch & handover to mechanical — U-24 Fractionation | 11d | 2025-10-12 | 2025-10-27 | A5070 SS+3d |  |  |
| A5100 | Secondary steel & bracing — U-25 Utilities | 22d | 2025-10-15 | 2025-11-16 | A5090 SS+6d |  |  |
| A5110 | Pipe-rack erection — U-25 Utilities | 12d | 2025-10-23 | 2025-11-10 | A5100 SS+3d, A2690 SS, A5520 SS |  |  |
| A5130 | Fireproofing — U-25 Utilities | 21d | 2025-10-25 | 2025-11-24 | A5120 SS+5d, A6020 SS, A2690 SS |  |  |
| A5120 | Platforms, stairs & ladders — U-25 Utilities | 25d | 2025-10-26 | 2025-11-28 | A5110 SS+9d |  |  |
| A5140 | Survey & alignment checks — U-25 Utilities | 13d | 2025-10-27 | 2025-11-13 | A5130 SS+5d, A5120 SS, A5540 SS |  |  |
| A5150 | Punch & handover to mechanical — U-25 Utilities | 17d | 2025-11-04 | 2025-11-27 | A5140 SS+4d, A2710 SS, A5550 SS, A6050 SS |  |  |
| A5160 | Main steel erection — U-26 Offsites & Flare | 17d | 2025-11-06 | 2025-12-01 | A5150 SS+10d, A6060 SS, A5560 SS |  |  |
| A5170 | Secondary steel & bracing — U-26 Offsites & Flare | 17d | 2025-11-14 | 2025-12-09 | A5160 SS+9d |  |  |
| A5180 | Pipe-rack erection — U-26 Offsites & Flare | 15d | 2025-11-16 | 2025-12-05 | A5170 SS+7d, A3890 SS |  |  |
| A5190 | Platforms, stairs & ladders — U-26 Offsites & Flare | 22d | 2025-11-16 | 2025-12-16 | A5180 SS+9d |  |  |
| A5200 | Fireproofing — U-26 Offsites & Flare | 26d | 2025-11-20 | 2025-12-27 | A5190 SS+5d |  |  |
| A5210 | Survey & alignment checks — U-26 Offsites & Flare | 11d | 2025-11-24 | 2025-12-09 | A5200 SS+8d, A3900 SS, A5590 SS |  |  |
| A5220 | Punch & handover to mechanical — U-26 Offsites & Flare | 27d | 2025-11-26 | 2026-01-02 | A5210 SS+5d, A5200 SS, A3900 SS |  |  |
| A5230 | Main steel erection — batch 7 | 13d | 2025-12-02 | 2025-12-19 | A5220 SS+6d, A6130 SS, A5600 SS |  |  |
| A5240 | Secondary steel & bracing — batch 7 | 10d | 2025-12-05 | 2025-12-20 | A5230 SS+7d, A6140 SS, A6980 SS |  |  |
| A5250 | Pipe-rack erection — batch 7 | 25d | 2025-12-14 | 2026-01-17 | A5240 SS+9d |  |  |
| A5270 | Fireproofing — batch 7 | 18d | 2025-12-15 | 2026-01-08 | A5260 SS+10d, A5250 SS, A6180 SS |  |  |
| A5260 | Platforms, stairs & ladders — batch 7 | 13d | 2025-12-16 | 2026-01-04 | A5250 SS+3d |  |  |
| A5280 | Survey & alignment checks — batch 7 | 17d | 2025-12-24 | 2026-01-17 | A5270 SS+5d, A5660 SS, A7020 SS |  |  |
| A5290 | Punch & handover to mechanical — batch 7 | 10d | 2025-12-26 | 2026-01-10 | A5280 SS+7d |  |  |
| A5300 | Main steel erection — batch 8 | 20d | 2025-12-26 | 2026-01-24 | A5290 SS+8d, A5670 SS, A5660 SS |  |  |
| A5310 | Secondary steel & bracing — batch 8 | 26d | 2026-01-01 | 2026-02-08 | A5300 SS+10d |  |  |
| A5330 | Platforms, stairs & ladders — batch 8 | 11d | 2026-01-08 | 2026-01-25 | A5320 SS+7d, A5690 SS, A7060 SS |  |  |
| A5320 | Pipe-rack erection — batch 8 | 25d | 2026-01-10 | 2026-02-13 | A5310 SS+9d, A5700 SS, A6250 SS |  |  |
| A5340 | Fireproofing — batch 8 | 22d | 2026-01-13 | 2026-02-12 | A5330 SS+8d, A6260 SS, A5700 SS |  |  |
| A5350 | Survey & alignment checks — batch 8 | 25d | 2026-01-17 | 2026-02-21 | A5340 SS+6d |  |  |
| A5370 | Main steel erection — batch 9 | 22d | 2026-01-22 | 2026-02-23 | A5360 SS+5d |  |  |
| A5360 | Punch & handover to mechanical — batch 8 | 25d | 2026-01-25 | 2026-03-01 | A5350 SS+5d |  |  |
| A5380 | Secondary steel & bracing — batch 9 | 11d | 2026-01-29 | 2026-02-15 | A5370 SS+3d, A7580 SS, A5360 SS |  |  |
| A5390 | Pipe-rack erection — batch 9 | 25d | 2026-01-30 | 2026-03-06 | A5380 SS+10d, A7090 SS, A7580 SS |  |  |
| A5400 | Platforms, stairs & ladders — batch 9 | 14d | 2026-02-04 | 2026-02-24 | A5390 SS+5d, A6340 SS, A5740 SS |  |  |
| A5410 | Fireproofing — batch 9 | 15d | 2026-02-15 | 2026-03-06 | A5400 SS+6d, A6380 SS, A6370 SS |  |  |

| ID | Activity | Duration | Start | Finish | Predecessors | Complete | Remaining |
| --- | --- | --- | --- | --- | --- | --- | --- |
|  | **Mechanical & Piping** |  | 2025-09-01 | 2026-09-18 |  |  |  |
|  | **Equipment Setting & Alignment** |  | 2025-09-01 | 2026-04-17 |  |  |  |
| A5420 | Heavy lift — columns & vessels | 19d | 2025-09-01 | 2025-09-26 | A3130 | 100% |  |
| A5430 | Equipment setting — static | 15d | 2025-09-07 | 2025-09-27 | A5420 SS+6d | 100% |  |
| A5440 | Equipment setting — rotating | 21d | 2025-09-11 | 2025-10-12 | A5430 SS+4d, A3410 SS+11d |  | 21d |
| A5450 | Compressor installation | 16d | 2025-09-16 | 2025-10-08 | A5440 SS+8d, A3790 SS |  | 16d |
| A5460 | Skid & package installation | 14d | 2025-09-17 | 2025-10-07 | A5450 SS+5d |  | 14d |
| A5470 | Alignment & grouting | 13d | 2025-09-26 | 2025-10-15 | A5460 SS+4d |  | 13d |
| A5480 | Internals installation | 12d | 2025-09-26 | 2025-10-14 | A5470 SS+3d, A5930 SS, A2340 SS |  | 12d |
| A5490 | Heavy lift — columns & vessels — U-21 Inlet & Metering | 24d | 2025-10-06 | 2025-11-07 | A5480 SS+6d, A5060 SS, A3820 SS |  |  |
| A5510 | Equipment setting — rotating — U-21 Inlet & Metering | 14d | 2025-10-10 | 2025-10-30 | A5500 SS+10d, A3830 SS, A5980 SS |  |  |
| A5500 | Equipment setting — static — U-21 Inlet & Metering | 25d | 2025-10-11 | 2025-11-15 | A5490 SS+3d, A5990 SS, A3830 SS |  |  |
| A5520 | Compressor installation — U-21 Inlet & Metering | 14d | 2025-10-20 | 2025-11-08 | A5510 SS+7d |  |  |
| A5530 | Skid & package installation — U-21 Inlet & Metering | 16d | 2025-10-22 | 2025-11-13 | A5520 SS+8d, A5100 SS |  |  |
| A5540 | Alignment & grouting — U-21 Inlet & Metering | 13d | 2025-10-25 | 2025-11-12 | A5530 SS+4d |  |  |
| A5550 | Internals installation — U-21 Inlet & Metering | 21d | 2025-10-30 | 2025-11-30 | A5540 SS+6d |  |  |
| A5560 | Heavy lift — columns & vessels — U-22 Compression | 17d | 2025-11-02 | 2025-11-25 | A5550 SS+5d |  |  |
| A5570 | Equipment setting — static — U-22 Compression | 25d | 2025-11-14 | 2025-12-19 | A5560 SS+5d, A3890 SS, A6080 SS |  |  |
| A5580 | Equipment setting — rotating — U-22 Compression | 28d | 2025-11-17 | 2025-12-25 | A5570 SS+7d, A3910 SS, A5170 SS |  |  |
| A5590 | Compressor installation — U-22 Compression | 24d | 2025-11-17 | 2025-12-19 | A5580 SS+9d |  |  |
| A5600 | Skid & package installation — U-22 Compression | 26d | 2025-11-24 | 2025-12-30 | A5590 SS+8d |  |  |
| A5610 | Alignment & grouting — U-22 Compression | 25d | 2025-11-30 | 2026-01-04 | A5600 SS+7d, A5200 SS |  |  |
| A5620 | Internals installation — U-22 Compression | 13d | 2025-12-05 | 2025-12-24 | A5610 SS+3d |  |  |
| A5630 | Heavy lift — columns & vessels — U-23 Dehydration | 13d | 2025-12-11 | 2025-12-30 | A5620 SS+7d |  |  |
| A5640 | Equipment setting — static — U-23 Dehydration | 18d | 2025-12-16 | 2026-01-09 | A5630 SS+3d, A7000 SS, A5250 SS |  |  |
| A5650 | Equipment setting — rotating — U-23 Dehydration | 12d | 2025-12-17 | 2026-01-02 | A5640 SS+3d |  |  |
| A5660 | Compressor installation — U-23 Dehydration | 18d | 2025-12-21 | 2026-01-14 | A5650 SS+5d |  |  |
| A5670 | Skid & package installation — U-23 Dehydration | 20d | 2025-12-22 | 2026-01-19 | A5660 SS+9d |  |  |
| A5680 | Alignment & grouting — U-23 Dehydration | 20d | 2026-01-04 | 2026-01-31 | A5670 SS+9d, A5310 SS, A6230 SS |  |  |
| A5690 | Internals installation — U-23 Dehydration | 11d | 2026-01-05 | 2026-01-20 | A5680 SS+6d |  |  |
| A5700 | Heavy lift — columns & vessels — U-24 Fractionation | 18d | 2026-01-09 | 2026-02-04 | A5690 SS+7d |  |  |
| A5710 | Equipment setting — static — U-24 Fractionation | 15d | 2026-01-09 | 2026-01-30 | A5700 SS+5d, A6250 SS, A7540 SS |  |  |
| A5720 | Equipment setting — rotating — U-24 Fractionation | 21d | 2026-01-17 | 2026-02-16 | A5710 SS+3d, A7550 SS, A7070 SS |  |  |
| A5730 | Compressor installation — U-24 Fractionation | 25d | 2026-01-24 | 2026-02-28 | A5720 SS+7d, A5370 SS, A6290 SS |  |  |
| A5740 | Skid & package installation — U-24 Fractionation | 15d | 2026-01-30 | 2026-02-22 | A5730 SS+9d |  |  |
| A5750 | Alignment & grouting — U-24 Fractionation | 16d | 2026-01-30 | 2026-02-23 | A5740 SS+5d, A7110 SS, A7090 SS |  |  |
| A5760 | Internals installation — U-24 Fractionation | 15d | 2026-02-08 | 2026-02-27 | A5750 SS+6d, A7120 SS, A7590 SS |  |  |
| A5770 | Heavy lift — columns & vessels — U-25 Utilities | 27d | 2026-02-11 | 2026-03-20 | A5760 SS+6d, A6350 SS, A7120 SS |  |  |
| A5780 | Equipment setting — static — U-25 Utilities | 16d | 2026-02-17 | 2026-03-11 | A5770 SS+5d, A7610 SS, A6380 SS |  |  |
| A5790 | Equipment setting — rotating — U-25 Utilities | 25d | 2026-02-22 | 2026-03-27 | A5780 SS+5d |  |  |
| A5800 | Compressor installation — U-25 Utilities | 21d | 2026-02-24 | 2026-03-25 | A5790 SS+3d |  |  |
| A5810 | Skid & package installation — U-25 Utilities | 12d | 2026-03-04 | 2026-03-21 | A5800 SS+3d, A7640 SS |  |  |
| A5820 | Alignment & grouting — U-25 Utilities | 25d | 2026-03-09 | 2026-04-13 | A5810 SS+4d, A7660 SS, A7650 SS |  |  |
| A5840 | Heavy lift — columns & vessels — U-26 Offsites & Flare | 28d | 2026-03-10 | 2026-04-17 | A5830 SS+3d, A7180 SS, A7660 SS |  |  |
| A5830 | Internals installation — U-25 Utilities | 20d | 2026-03-11 | 2026-04-08 | A5820 SS+9d |  |  |
| A5850 | Equipment setting — static — U-26 Offsites & Flare | 25d | 2026-03-15 | 2026-04-17 | A5840 SS+4d |  |  |
| A5860 | Equipment setting — rotating — U-26 Offsites & Flare | 15d | 2026-03-28 | 2026-04-17 | A5850 SS+6d, A7690 SS, A6470 SS |  |  |

| ID | Activity | Duration | Start | Finish | Predecessors | Complete | Remaining |
| --- | --- | --- | --- | --- | --- | --- | --- |
|  | **Piping Spool Fab. & Install** |  | 2025-09-01 | 2026-09-18 |  |  |  |
| A5870 | Spool fabrication | 14d | 2025-09-01 | 2025-09-19 | A4740 SS+82d, A3420 SS+237d, A2300 SS, A2650 SS | 100% |  |
| A5880 | Spool delivery & staging | 25d | 2025-09-06 | 2025-10-10 | A5870 SS+8d |  | 25d |
| A5890 | Large-bore erection | 25d | 2025-09-06 | 2025-10-12 | A5880 SS+9d, A2310 SS, A3780 SS |  | 25d |
| A5900 | Small-bore & supports | 16d | 2025-09-07 | 2025-09-29 | A5890 SS+9d, A5880 SS, A2310 SS | 100% |  |
| A5910 | Field welding & NDE | 17d | 2025-09-16 | 2025-10-09 | A5900 SS+4d |  | 17d |
| A5920 | Bolted joints & torquing | 22d | 2025-09-17 | 2025-10-18 | A5910 SS+8d, A2330 SS |  | 22d |
| A5930 | Punch & reinstatement | 15d | 2025-09-21 | 2025-10-10 | A5920 SS+10d |  | 15d |
| A5940 | Spool fabrication — U-21 Inlet & Metering | 18d | 2025-09-22 | 2025-10-16 | A5930 SS+7d, A2340 SS, A5030 SS |  | 18d |
| A5950 | Spool delivery & staging — U-21 Inlet & Metering | 11d | 2025-09-30 | 2025-10-15 | A5940 SS+5d, A5470 SS, A5930 SS |  | 11d |
| A5960 | Large-bore erection — U-21 Inlet & Metering | 25d | 2025-10-01 | 2025-11-05 | A5950 SS+9d, A5050 SS, A5470 SS |  |  |
| A5970 | Small-bore & supports — U-21 Inlet & Metering | 25d | 2025-10-05 | 2025-11-09 | A5960 SS+5d |  |  |
| A5980 | Field welding & NDE — U-21 Inlet & Metering | 14d | 2025-10-06 | 2025-10-25 | A5970 SS+9d |  |  |
| A5990 | Bolted joints & torquing — U-21 Inlet & Metering | 24d | 2025-10-08 | 2025-11-11 | A5980 SS+7d |  |  |
| A6000 | Punch & reinstatement — U-21 Inlet & Metering | 26d | 2025-10-17 | 2025-11-24 | A5990 SS+5d, A5080 SS, A5090 SS |  |  |
| A6010 | Spool fabrication — U-22 Compression | 22d | 2025-10-20 | 2025-11-19 | A6000 SS+4d, A5100 SS, A5080 SS |  |  |
| A6020 | Spool delivery & staging — U-22 Compression | 15d | 2025-10-22 | 2025-11-12 | A6010 SS+4d |  |  |
| A6030 | Large-bore erection — U-22 Compression | 13d | 2025-10-26 | 2025-11-12 | A6020 SS+6d, A5540 SS, A3860 SS |  |  |
| A6040 | Small-bore & supports — U-22 Compression | 13d | 2025-10-26 | 2025-11-12 | A6030 SS+6d |  |  |
| A6050 | Field welding & NDE — U-22 Compression | 15d | 2025-10-29 | 2025-11-19 | A6040 SS+8d |  |  |
| A6060 | Bolted joints & torquing — U-22 Compression | 14d | 2025-11-04 | 2025-11-24 | A6050 SS+9d |  |  |
| A6070 | Punch & reinstatement — U-22 Compression | 13d | 2025-11-04 | 2025-11-23 | A6060 SS+7d, A5560 SS, A5550 SS |  |  |
| A6080 | Spool fabrication — U-23 Dehydration | 26d | 2025-11-06 | 2025-12-13 | A6070 SS+5d |  |  |
| A6100 | Large-bore erection — U-23 Dehydration | 17d | 2025-11-12 | 2025-12-06 | A6090 SS+10d, A3880 SS, A6060 SS |  |  |
| A6090 | Spool delivery & staging — U-23 Dehydration | 21d | 2025-11-13 | 2025-12-12 | A6080 SS+10d, A3880 SS |  |  |
| A6120 | Field welding & NDE — U-23 Dehydration | 28d | 2025-11-18 | 2025-12-26 | A6110 SS+5d, A5190 SS, A3910 SS |  |  |
| A6110 | Small-bore & supports — U-23 Dehydration | 12d | 2025-11-19 | 2025-12-06 | A6100 SS+7d, A5590 SS, A5190 SS |  |  |
| A6130 | Bolted joints & torquing — U-23 Dehydration | 23d | 2025-11-27 | 2025-12-30 | A6120 SS+9d |  |  |
| A6140 | Punch & reinstatement — U-23 Dehydration | 13d | 2025-12-02 | 2025-12-20 | A6130 SS+3d |  |  |
| A6150 | Spool fabrication — U-24 Fractionation | 17d | 2025-12-03 | 2025-12-26 | A6140 SS+5d, A6980 SS, A6130 SS |  |  |
| A6160 | Spool delivery & staging — U-24 Fractionation | 13d | 2025-12-07 | 2025-12-24 | A6150 SS+3d, A6990 SS, A6140 SS |  |  |
| A6170 | Large-bore erection — U-24 Fractionation | 16d | 2025-12-11 | 2026-01-02 | A6160 SS+7d, A5620 SS, A6990 SS |  |  |
| A6180 | Small-bore & supports — U-24 Fractionation | 19d | 2025-12-11 | 2026-01-07 | A6170 SS+10d |  |  |
| A6190 | Field welding & NDE — U-24 Fractionation | 20d | 2025-12-14 | 2026-01-10 | A6180 SS+9d, A5630 SS |  |  |
| A6200 | Bolted joints & torquing — U-24 Fractionation | 17d | 2025-12-18 | 2026-01-12 | A6190 SS+7d, A5260 SS, A7000 SS |  |  |
| A6210 | Punch & reinstatement — U-24 Fractionation | 22d | 2025-12-20 | 2026-01-20 | A6200 SS+8d, A5650 SS, A5260 SS |  |  |
| A6220 | Spool fabrication — U-25 Utilities | 25d | 2025-12-21 | 2026-01-24 | A6210 SS+5d, A7020 SS, A5650 SS |  |  |
| A6230 | Spool delivery & staging — U-25 Utilities | 18d | 2025-12-31 | 2026-01-26 | A6220 SS+6d |  |  |
| A6240 | Large-bore erection — U-25 Utilities | 13d | 2025-12-31 | 2026-01-19 | A6230 SS+4d, A7030 SS, A5290 SS |  |  |
| A6250 | Small-bore & supports — U-25 Utilities | 16d | 2026-01-08 | 2026-01-30 | A6240 SS+4d |  |  |
| A6270 | Bolted joints & torquing — U-25 Utilities | 16d | 2026-01-08 | 2026-01-31 | A6260 SS+6d, A7540 SS, A5690 SS |  |  |
| A6260 | Field welding & NDE — U-25 Utilities | 10d | 2026-01-09 | 2026-01-25 | A6250 SS+9d |  |  |
| A6280 | Punch & reinstatement — U-25 Utilities | 23d | 2026-01-17 | 2026-02-18 | A6270 SS+6d |  |  |
| A6300 | Spool delivery & staging — U-26 Offsites & Flare | 20d | 2026-01-18 | 2026-02-14 | A6290 SS+9d, A5350 SS, A7550 SS |  |  |
| A6290 | Spool fabrication — U-26 Offsites & Flare | 18d | 2026-01-20 | 2026-02-13 | A6280 SS+7d |  |  |
| A6310 | Large-bore erection — U-26 Offsites & Flare | 26d | 2026-01-22 | 2026-02-27 | A6300 SS+8d, A6290 SS, A6280 SS |  |  |
| A6320 | Small-bore & supports — U-26 Offsites & Flare | 13d | 2026-01-25 | 2026-02-11 | A6310 SS+5d, A7570 SS, A5370 SS |  |  |
| A6330 | Field welding & NDE — U-26 Offsites & Flare | 27d | 2026-01-26 | 2026-03-04 | A6320 SS+7d, A5360 SS, A7570 SS |  |  |
| A6340 | Bolted joints & torquing — U-26 Offsites & Flare | 20d | 2026-01-30 | 2026-02-27 | A6330 SS+5d |  |  |
| A6350 | Punch & reinstatement — U-26 Offsites & Flare | 21d | 2026-02-07 | 2026-03-09 | A6340 SS+7d |  |  |
| A6370 | Spool delivery & staging — batch 7 | 22d | 2026-02-11 | 2026-03-13 | A6360 SS+7d |  |  |
| A6360 | Spool fabrication — batch 7 | 25d | 2026-02-12 | 2026-03-19 | A6350 SS+3d, A7130 SS |  |  |
| A6380 | Large-bore erection — batch 7 | 12d | 2026-02-12 | 2026-03-02 | A6370 SS+3d |  |  |
| A6400 | Field welding & NDE — batch 7 | 11d | 2026-02-21 | 2026-03-09 | A6390 SS+5d, A7620 SS, A7610 SS |  |  |
| A6410 | Bolted joints & torquing — batch 7 | 20d | 2026-02-21 | 2026-03-21 | A6400 SS+3d |  |  |
| A6390 | Small-bore & supports — batch 7 | 20d | 2026-02-22 | 2026-03-20 | A6380 SS+3d, A6410 SS, A7160 SS |  |  |
| A6420 | Punch & reinstatement — batch 7 | 27d | 2026-03-02 | 2026-04-08 | A6410 SS+6d |  |  |
| A6430 | Spool fabrication — batch 8 | 16d | 2026-03-05 | 2026-03-27 | A6420 SS+6d, A7640 SS |  |  |
| A6450 | Large-bore erection — batch 8 | 13d | 2026-03-07 | 2026-03-25 | A6440 SS+10d, A7650 SS, A6420 SS |  |  |
| A6440 | Spool delivery & staging — batch 8 | 26d | 2026-03-09 | 2026-04-14 | A6430 SS+8d |  |  |
| A6460 | Small-bore & supports — batch 8 | 17d | 2026-03-11 | 2026-04-03 | A6450 SS+6d, A7190 SS, A6440 SS |  |  |
| A6480 | Bolted joints & torquing — batch 8 | 24d | 2026-03-18 | 2026-04-21 | A6470 SS+3d, A5850 SS, A5830 SS |  |  |
| A6470 | Field welding & NDE — batch 8 | 13d | 2026-03-19 | 2026-04-07 | A6460 SS+9d |  |  |
| A6490 | Punch & reinstatement — batch 8 | 14d | 2026-03-23 | 2026-04-11 | A6480 SS+9d, A6470 SS, A7670 SS |  |  |
| A6510 | Spool delivery & staging — batch 9 | 20d | 2026-03-28 | 2026-04-25 | A6500 SS+10d |  |  |
| A6500 | Spool fabrication — batch 9 | 24d | 2026-03-30 | 2026-05-01 | A6490 SS+5d, A5860 SS, A7220 SS, A7690 SS |  |  |
| A6520 | Large-bore erection — batch 9 | 25d | 2026-04-04 | 2026-05-10 | A6510 SS+8d |  |  |
| A6530 | Small-bore & supports — batch 9 | 26d | 2026-04-05 | 2026-05-11 | A6520 SS+7d, A7700 SS, A7230 SS |  |  |
| A6550 | Bolted joints & torquing — batch 9 | 25d | 2026-04-09 | 2026-05-14 | A6540 SS+6d, A6520 SS, A7700 SS |  |  |
| A6540 | Field welding & NDE — batch 9 | 15d | 2026-04-11 | 2026-05-03 | A6530 SS+6d |  |  |

| ID | Activity | Type | Duration | Start | Finish | Predecessors |
| --- | --- | --- | --- | --- | --- | --- |
| A6560 | Punch & reinstatement — batch 9 |  | 19d | 2026-04-12 | 2026-05-07 | A6550 SS+8d, A7260 SS, A7250 SS |
| A6970 | M3 — 50% piping erected | milestone | 0d | 2026-04-15 | 2026-04-15 | A6420 FF |
| A6570 | Spool fabrication — batch 10 |  | 20d | 2026-04-17 | 2026-05-15 | A6560 SS+8d, A6970 |
| A6580 | Spool delivery & staging — batch 10 |  | 25d | 2026-04-20 | 2026-05-25 | A6570 SS+8d |
| A6590 | Large-bore erection — batch 10 |  | 13d | 2026-04-28 | 2026-05-16 | A6580 SS+5d |
| A6610 | Field welding & NDE — batch 10 |  | 14d | 2026-04-28 | 2026-05-18 | A6600 SS+3d, A6580 SS, A7750 SS |
| A6600 | Small-bore & supports — batch 10 |  | 19d | 2026-05-01 | 2026-05-28 | A6590 SS+4d |
| A6620 | Bolted joints & torquing — batch 10 |  | 14d | 2026-05-04 | 2026-05-24 | A6610 SS+8d, A6600 SS, A7290 SS |
| A6630 | Punch & reinstatement — batch 10 |  | 26d | 2026-05-05 | 2026-06-10 | A6620 SS+4d, A7310 SS, A6600 SS |
| A6640 | Spool fabrication — batch 11 |  | 20d | 2026-05-08 | 2026-06-05 | A6630 SS+8d |
| A6660 | Large-bore erection — batch 11 |  | 17d | 2026-05-14 | 2026-06-08 | A6650 SS+5d |
| A6650 | Spool delivery & staging — batch 11 |  | 20d | 2026-05-15 | 2026-06-14 | A6640 SS+10d |
| A6670 | Small-bore & supports — batch 11 |  | 20d | 2026-05-25 | 2026-06-22 | A6660 SS+6d |
| A6690 | Bolted joints & torquing — batch 11 |  | 25d | 2026-05-26 | 2026-06-30 | A6680 SS+5d, A7800 SS, A6650 SS |
| A6680 | Field welding & NDE — batch 11 |  | 18d | 2026-05-27 | 2026-06-22 | A6670 SS+6d, A7800 SS |
| A6700 | Punch & reinstatement — batch 11 |  | 25d | 2026-05-29 | 2026-07-05 | A6690 SS+7d, A7350 SS, A6670 SS |
| A6710 | Spool fabrication — batch 12 |  | 18d | 2026-06-02 | 2026-06-26 | A6700 SS+6d |
| A6720 | Spool delivery & staging — batch 12 |  | 16d | 2026-06-06 | 2026-06-29 | A6710 SS+3d |
| A6730 | Large-bore erection — batch 12 |  | 12d | 2026-06-11 | 2026-06-29 | A6720 SS+4d, A7850 SS |
| A6740 | Small-bore & supports — batch 12 |  | 16d | 2026-06-12 | 2026-07-06 | A6730 SS+3d |
| A6750 | Field welding & NDE — batch 12 |  | 27d | 2026-06-14 | 2026-07-21 | A6740 SS+5d, A7390 SS, A7850 SS |
| A6760 | Bolted joints & torquing — batch 12 |  | 28d | 2026-06-23 | 2026-07-31 | A6750 SS+8d, A7860 SS, A6740 SS |
| A6770 | Punch & reinstatement — batch 12 |  | 25d | 2026-06-23 | 2026-07-28 | A6760 SS+8d |
| A6780 | Spool fabrication — batch 13 |  | 17d | 2026-06-28 | 2026-07-21 | A6770 SS+10d |
| A6800 | Large-bore erection — batch 13 |  | 15d | 2026-06-30 | 2026-07-21 | A6790 SS+4d |
| A6790 | Spool delivery & staging — batch 13 |  | 20d | 2026-07-03 | 2026-07-31 | A6780 SS+4d |
| A6810 | Small-bore & supports — batch 13 |  | 17d | 2026-07-08 | 2026-07-31 | A6800 SS+4d, A6790 SS |
| A6830 | Bolted joints & torquing — batch 13 |  | 20d | 2026-07-12 | 2026-08-07 | A6820 SS+3d |
| A6820 | Field welding & NDE — batch 13 |  | 14d | 2026-07-14 | 2026-08-03 | A6810 SS+9d |
| A6840 | Punch & reinstatement — batch 13 |  | 21d | 2026-07-19 | 2026-08-17 | A6830 SS+4d |
| A6850 | Spool fabrication — batch 14 |  | 17d | 2026-07-19 | 2026-08-11 | A6840 SS+7d, A6820 SS, A6830 SS |
| A6860 | Spool delivery & staging — batch 14 |  | 15d | 2026-07-26 | 2026-08-14 | A6850 SS+7d |
| A6870 | Large-bore erection — batch 14 |  | 14d | 2026-07-27 | 2026-08-14 | A6860 SS+4d, A7950 SS, A7480 SS |
| A6880 | Small-bore & supports — batch 14 |  | 13d | 2026-07-30 | 2026-08-18 | A6870 SS+6d |
| A6890 | Field welding & NDE — batch 14 |  | 12d | 2026-08-03 | 2026-08-19 | A6880 SS+7d, A8140 SS |
| A6900 | Bolted joints & torquing — batch 14 |  | 19d | 2026-08-03 | 2026-08-28 | A6890 SS+10d |
| A6910 | Punch & reinstatement — batch 14 |  | 11d | 2026-08-06 | 2026-08-23 | A6900 SS+8d |
| A6920 | Spool fabrication — batch 15 |  | 27d | 2026-08-12 | 2026-09-18 | A6910 SS+4d |
| A6940 | Large-bore erection — batch 15 |  | 27d | 2026-08-12 | 2026-09-18 | A6930 SS+10d, A7980 SS, A7970 SS |
| A6960 | Field welding & NDE — batch 15 |  | 24d | 2026-08-17 | 2026-09-18 | A6950 SS+8d |
| A6930 | Spool delivery & staging — batch 15 |  | 12d | 2026-08-19 | 2026-09-06 | A6920 SS+9d |
| A6950 | Small-bore & supports — batch 15 |  | 12d | 2026-08-23 | 2026-09-08 | A6940 SS+5d |

| ID | Activity | Duration | Start | Finish | Predecessors |
| --- | --- | --- | --- | --- | --- |
|  | **Electrical & Instrumentation** |  | 2025-12-01 | 2026-10-16 |  |
|  | **HV/LV Electrical Installation** |  | 2025-12-01 | 2026-09-04 |  |
| A6980 | Cable tray & conduit | 19d | 2025-12-01 | 2025-12-26 | A4740 SS+179d |
| A6990 | HV cable pulling | 13d | 2025-12-03 | 2025-12-22 | A6980 SS+6d |
| A7010 | Cable termination & glanding | 11d | 2025-12-11 | 2025-12-27 | A7000 SS+3d, A5620 SS |
| A7000 | LV & control cable pulling | 20d | 2025-12-14 | 2026-01-11 | A6990 SS+5d |
| A7020 | Substation equipment installation | 11d | 2025-12-19 | 2026-01-05 | A7010 SS+7d |
| A7030 | Lighting & small power | 25d | 2025-12-28 | 2026-01-30 | A7020 SS+4d |
| A7040 | Earthing connections & testing | 14d | 2025-12-29 | 2026-01-18 | A7030 SS+5d, A5290 SS, A5670 SS |
| A7050 | Cable tray & conduit — U-21 Inlet & Metering | 23d | 2026-01-03 | 2026-02-04 | A7040 SS+9d, A6230 SS, A7030 SS |
| A7060 | HV cable pulling — U-21 Inlet & Metering | 26d | 2026-01-03 | 2026-02-09 | A7050 SS+7d |
| A7070 | LV & control cable pulling — U-21 Inlet & Metering | 10d | 2026-01-10 | 2026-01-25 | A7060 SS+3d |
| A7080 | Cable termination & glanding — U-21 Inlet & Metering | 25d | 2026-01-21 | 2026-02-25 | A7070 SS+3d, A6280 SS, A5350 SS |
| A7090 | Substation equipment installation — U-21 Inlet & Metering | 23d | 2026-01-26 | 2026-02-26 | A7080 SS+5d |
| A7110 | Earthing connections & testing — U-21 Inlet & Metering | 23d | 2026-01-29 | 2026-03-03 | A7100 SS+10d |
| A7100 | Lighting & small power — U-21 Inlet & Metering | 18d | 2026-01-30 | 2026-02-25 | A7090 SS+10d |
| A7120 | Cable tray & conduit — U-22 Compression | 13d | 2026-02-04 | 2026-02-23 | A7110 SS+6d |
| A7130 | HV cable pulling — U-22 Compression | 23d | 2026-02-10 | 2026-03-15 | A7120 SS+6d |
| A7140 | LV & control cable pulling — U-22 Compression | 16d | 2026-02-12 | 2026-03-06 | A7130 SS+6d, A6370 SS |
| A7160 | Substation equipment installation — U-22 Compression | 25d | 2026-02-20 | 2026-03-28 | A7150 SS+5d |
| A7150 | Cable termination & glanding — U-22 Compression | 20d | 2026-02-21 | 2026-03-21 | A7140 SS+5d, A7620 SS |
| A7170 | Lighting & small power — U-22 Compression | 18d | 2026-02-24 | 2026-03-20 | A7160 SS+8d, A5790 SS, A6410 SS |
| A7180 | Earthing connections & testing — U-22 Compression | 25d | 2026-03-07 | 2026-04-10 | A7170 SS+4d |
| A7190 | Cable tray & conduit — U-23 Dehydration | 23d | 2026-03-10 | 2026-04-11 | A7180 SS+6d |
| A7200 | HV cable pulling — U-23 Dehydration | 18d | 2026-03-10 | 2026-04-05 | A7190 SS+6d, A6440 SS, A7180 SS |
| A7210 | LV & control cable pulling — U-23 Dehydration | 20d | 2026-03-15 | 2026-04-10 | A7200 SS+4d, A5830 SS, A7190 SS |
| A7220 | Cable termination & glanding — U-23 Dehydration | 25d | 2026-03-25 | 2026-04-29 | A7210 SS+3d |
| A7230 | Substation equipment installation — U-23 Dehydration | 21d | 2026-03-30 | 2026-04-28 | A7220 SS+3d |
| A7240 | Lighting & small power — U-23 Dehydration | 10d | 2026-04-03 | 2026-04-19 | A7230 SS+3d, A6510 SS |
| A7250 | Earthing connections & testing — U-23 Dehydration | 12d | 2026-04-08 | 2026-04-24 | A7240 SS+7d |
| A7260 | Cable tray & conduit — U-24 Fractionation | 11d | 2026-04-10 | 2026-04-27 | A7250 SS+10d |
| A7270 | HV cable pulling — U-24 Fractionation | 15d | 2026-04-18 | 2026-05-08 | A7260 SS+8d, A6970, A6540 SS |
| A7280 | LV & control cable pulling — U-24 Fractionation | 12d | 2026-04-25 | 2026-05-12 | A7270 SS+8d, A7750 SS, A6570 SS |
| A7290 | Cable termination & glanding — U-24 Fractionation | 13d | 2026-04-28 | 2026-05-15 | A7280 SS+6d |
| A7300 | Substation equipment installation — U-24 Fractionation | 10d | 2026-05-01 | 2026-05-16 | A7290 SS+10d, A6590 SS |
| A7310 | Lighting & small power — U-24 Fractionation | 10d | 2026-05-02 | 2026-05-17 | A7300 SS+8d |
| A7320 | Earthing connections & testing — U-24 Fractionation | 18d | 2026-05-08 | 2026-06-03 | A7310 SS+4d, A7770 SS |
| A7330 | Cable tray & conduit — U-25 Utilities | 21d | 2026-05-14 | 2026-06-13 | A7320 SS+6d, A7780 SS, A6640 SS |
| A7340 | HV cable pulling — U-25 Utilities | 15d | 2026-05-16 | 2026-06-05 | A7330 SS+5d, A6660 SS, A7780 SS |
| A7350 | LV & control cable pulling — U-25 Utilities | 12d | 2026-05-26 | 2026-06-11 | A7340 SS+8d |
| A7360 | Cable termination & glanding — U-25 Utilities | 24d | 2026-05-27 | 2026-06-30 | A7350 SS+4d |
| A7370 | Substation equipment installation — U-25 Utilities | 13d | 2026-06-02 | 2026-06-20 | A7360 SS+10d, A7820 SS |
| A7380 | Lighting & small power — U-25 Utilities | 28d | 2026-06-09 | 2026-07-17 | A7370 SS+9d, A6720 SS, A6710 SS |
| A7390 | Earthing connections & testing — U-25 Utilities | 18d | 2026-06-09 | 2026-07-04 | A7380 SS+4d |
| A7400 | Cable tray & conduit — U-26 Offsites & Flare | 19d | 2026-06-18 | 2026-07-15 | A7390 SS+5d, A6740 SS |
| A7410 | HV cable pulling — U-26 Offsites & Flare | 17d | 2026-06-24 | 2026-07-19 | A7400 SS+3d, A7870 SS, A7860 SS |
| A7420 | LV & control cable pulling — U-26 Offsites & Flare | 10d | 2026-06-27 | 2026-07-12 | A7410 SS+9d, A6770 SS, A7870 SS |
| A7430 | Cable termination & glanding — U-26 Offsites & Flare | 25d | 2026-06-28 | 2026-08-01 | A7420 SS+9d, A7880 SS, A6770 SS |
| A7440 | Substation equipment installation — U-26 Offsites & Flare | 25d | 2026-07-01 | 2026-08-05 | A7430 SS+5d, A7890 SS, A6780 SS |
| A7450 | Lighting & small power — U-26 Offsites & Flare | 27d | 2026-07-08 | 2026-08-14 | A7440 SS+6d |
| A7460 | Earthing connections & testing — U-26 Offsites & Flare | 13d | 2026-07-14 | 2026-08-01 | A7450 SS+6d, A6830 SS, A7910 SS |
| A7470 | Cable tray & conduit — batch 7 | 20d | 2026-07-19 | 2026-08-14 | A7460 SS+5d |
| A7480 | HV cable pulling — batch 7 | 26d | 2026-07-23 | 2026-08-28 | A7470 SS+6d |
| A7490 | LV & control cable pulling — batch 7 | 23d | 2026-07-29 | 2026-08-31 | A7480 SS+9d, A6860 SS, A7950 SS |
| A7510 | Substation equipment installation — batch 7 | 13d | 2026-08-04 | 2026-08-22 | A7500 SS+3d |
| A7500 | Cable termination & glanding — batch 7 | 11d | 2026-08-06 | 2026-08-22 | A7490 SS+7d, A6900 SS |
| A7520 | Lighting & small power — batch 7 | 16d | 2026-08-13 | 2026-09-04 | A7510 SS+7d |

| ID | Activity | Duration | Start | Finish | Predecessors |
| --- | --- | --- | --- | --- | --- |
|  | **Instrument & Control Systems** |  | 2026-01-05 | 2026-10-16 |  |
| A7530 | Instrument installation & hook-up | 22d | 2026-01-05 | 2026-02-04 | A5870 SS+109d, A7060 SS, A5310 SS |
| A7540 | Impulse lines & tubing | 15d | 2026-01-07 | 2026-01-28 | A7530 SS+10d |
| A7550 | DCS/SIS cabinet installation | 12d | 2026-01-14 | 2026-01-30 | A7540 SS+6d |
| A7560 | Marshalling & system cabinets | 20d | 2026-01-16 | 2026-02-13 | A7550 SS+5d, A7070 SS, A6260 SS |
| A7570 | Loop checks | 20d | 2026-01-23 | 2026-02-20 | A7560 SS+6d |
| A7580 | Function tests | 26d | 2026-01-25 | 2026-03-02 | A7570 SS+7d |
| A7590 | Telecoms & CCTV installation | 16d | 2026-02-03 | 2026-02-25 | A7580 SS+5d |
| A7600 | Instrument installation & hook-up — U-21 Inlet & Metering | 26d | 2026-02-04 | 2026-03-12 | A7590 SS+8d, A6340 SS |
| A7610 | Impulse lines & tubing — U-21 Inlet & Metering | 26d | 2026-02-12 | 2026-03-20 | A7600 SS+6d |
| A7620 | DCS/SIS cabinet installation — U-21 Inlet & Metering | 21d | 2026-02-16 | 2026-03-17 | A7610 SS+8d, A5410 SS |
| A7640 | Loop checks — U-21 Inlet & Metering | 18d | 2026-02-24 | 2026-03-20 | A7630 SS+10d |
| A7630 | Marshalling & system cabinets — U-21 Inlet & Metering | 17d | 2026-02-25 | 2026-03-21 | A7620 SS+7d, A5800 SS, A5790 SS |
| A7650 | Function tests — U-21 Inlet & Metering | 22d | 2026-03-04 | 2026-04-03 | A7640 SS+7d |
| A7660 | Telecoms & CCTV installation — U-21 Inlet & Metering | 20d | 2026-03-05 | 2026-04-02 | A7650 SS+8d |
| A7670 | Instrument installation & hook-up — U-22 Compression | 28d | 2026-03-17 | 2026-04-24 | A7660 SS+8d |
| A7680 | Impulse lines & tubing — U-22 Compression | 14d | 2026-03-20 | 2026-04-09 | A7670 SS+3d, A5850 SS |
| A7690 | DCS/SIS cabinet installation — U-22 Compression | 25d | 2026-03-20 | 2026-04-26 | A7680 SS+4d |
| A7710 | Loop checks — U-22 Compression | 27d | 2026-03-30 | 2026-05-06 | A7700 SS+8d, A6510 SS, A7220 SS |
| A7700 | Marshalling & system cabinets — U-22 Compression | 23d | 2026-04-01 | 2026-05-04 | A7690 SS+5d |
| A7720 | Function tests — U-22 Compression | 25d | 2026-04-10 | 2026-05-17 | A7710 SS+10d, A7250 SS, A6520 SS |
| A7730 | Telecoms & CCTV installation — U-22 Compression | 12d | 2026-04-15 | 2026-05-02 | A7720 SS+8d, A6540 SS, A7260 SS |
| A7750 | Impulse lines & tubing — U-23 Dehydration | 18d | 2026-04-18 | 2026-05-13 | A7740 SS+8d |
| A7740 | Instrument installation & hook-up — U-23 Dehydration | 15d | 2026-04-19 | 2026-05-10 | A7730 SS+5d, A6570 SS, A6970 |
| A7760 | DCS/SIS cabinet installation — U-23 Dehydration | 18d | 2026-04-28 | 2026-05-24 | A7750 SS+6d, A6580 SS |
| A7770 | Marshalling & system cabinets — U-23 Dehydration | 26d | 2026-05-04 | 2026-06-09 | A7760 SS+8d |
| A7780 | Loop checks — U-23 Dehydration | 10d | 2026-05-08 | 2026-05-24 | A7770 SS+4d |
| A7790 | Function tests — U-23 Dehydration | 28d | 2026-05-11 | 2026-06-18 | A7780 SS+8d, A6640 SS, A7770 SS |
| A7800 | Telecoms & CCTV installation — U-23 Dehydration | 23d | 2026-05-17 | 2026-06-17 | A7790 SS+4d |
| A7810 | Instrument installation & hook-up — U-24 Fractionation | 23d | 2026-05-21 | 2026-06-23 | A7800 SS+10d, A6650 SS, A6660 SS |
| A7820 | Impulse lines & tubing — U-24 Fractionation | 20d | 2026-05-29 | 2026-06-26 | A7810 SS+3d |
| A7830 | DCS/SIS cabinet installation — U-24 Fractionation | 28d | 2026-06-01 | 2026-07-09 | A7820 SS+10d, A7360 SS, A7350 SS |
| A7840 | Marshalling & system cabinets — U-24 Fractionation | 25d | 2026-06-06 | 2026-07-11 | A7830 SS+7d, A6710 SS, A7820 SS |
| A7850 | Loop checks — U-24 Fractionation | 14d | 2026-06-06 | 2026-06-25 | A7840 SS+5d |
| A7860 | Function tests — U-24 Fractionation | 16d | 2026-06-15 | 2026-07-07 | A7850 SS+4d |
| A7870 | Telecoms & CCTV installation — U-24 Fractionation | 15d | 2026-06-22 | 2026-07-13 | A7860 SS+9d |
| A7880 | Instrument installation & hook-up — U-25 Utilities | 12d | 2026-06-24 | 2026-07-11 | A7870 SS+7d |
| A7890 | Impulse lines & tubing — U-25 Utilities | 11d | 2026-06-28 | 2026-07-13 | A7880 SS+9d |
| A7900 | DCS/SIS cabinet installation — U-25 Utilities | 16d | 2026-06-28 | 2026-07-20 | A7890 SS+3d, A7880 SS |
| A7920 | Loop checks — U-25 Utilities | 12d | 2026-07-08 | 2026-07-25 | A7910 SS+5d, A8090 SS, A6790 SS |
| A7910 | Marshalling & system cabinets — U-25 Utilities | 27d | 2026-07-11 | 2026-08-18 | A7900 SS+7d |
| A7940 | Telecoms & CCTV installation — U-25 Utilities | 22d | 2026-07-20 | 2026-08-19 | A7930 SS+5d, A6840 SS, A6820 SS |
| A7930 | Function tests — U-25 Utilities | 13d | 2026-07-21 | 2026-08-07 | A7920 SS+3d |
| A7950 | Instrument installation & hook-up — U-26 Offsites & Flare | 13d | 2026-07-25 | 2026-08-12 | A7940 SS+9d |
| A7960 | Impulse lines & tubing — U-26 Offsites & Flare | 20d | 2026-07-31 | 2026-08-28 | A7950 SS+6d |
| A7970 | DCS/SIS cabinet installation — U-26 Offsites & Flare | 18d | 2026-08-09 | 2026-09-02 | A7960 SS+4d |
| A7980 | Marshalling & system cabinets — U-26 Offsites & Flare | 20d | 2026-08-10 | 2026-09-07 | A7970 SS+8d |
| A7990 | Loop checks — U-26 Offsites & Flare | 19d | 2026-08-11 | 2026-09-07 | A7980 SS+4d, A7970 SS, A6910 SS |
| A8000 | Function tests — U-26 Offsites & Flare | 16d | 2026-08-17 | 2026-09-08 | A7990 SS+6d, A7520 SS, A6920 SS |
| A8010 | Telecoms & CCTV installation — U-26 Offsites & Flare | 11d | 2026-08-21 | 2026-09-07 | A8000 SS+3d |
| A8020 | Instrument installation & hook-up — batch 7 | 23d | 2026-08-31 | 2026-10-01 | A8010 SS+8d, A8230 SS, A6950 SS |
| A8030 | Impulse lines & tubing — batch 7 | 12d | 2026-09-04 | 2026-09-22 | A8020 SS+7d |
| A8040 | DCS/SIS cabinet installation — batch 7 | 15d | 2026-09-05 | 2026-09-26 | A8030 SS+6d |
| A8070 | Function tests — batch 7 | 25d | 2026-09-12 | 2026-10-16 | A8060 SS+3d, A8300 SS, A8290 SS |
| A8050 | Marshalling & system cabinets — batch 7 | 16d | 2026-09-14 | 2026-10-06 | A8040 SS+4d |
| A8060 | Loop checks — batch 7 | 14d | 2026-09-21 | 2026-10-10 | A8050 SS+6d |

| ID | Activity | Type | Duration | Start | Finish | Predecessors | Complete |
| --- | --- | --- | --- | --- | --- | --- | --- |
|  | **Engineering** |  |  | 2024-01-08 | 2025-12-05 |  |  |
|  | **FEED & Conceptual Design** |  |  | 2024-01-08 | 2024-06-28 |  |  |
| A1000 | Concept screening & selection study |  | 19d | 2024-01-08 | 2024-02-04 |  | 100% |
| A1010 | Design basis memorandum |  | 26d | 2024-01-14 | 2024-02-19 | A1000 SS+8d | 100% |
| A1020 | Process simulations & H&MB |  | 23d | 2024-01-23 | 2024-02-23 | A1010 SS+7d | 100% |
| A1030 | PFD package — IFR |  | 12d | 2024-01-24 | 2024-02-09 | A1020 SS+4d, A1000 SS | 100% |
| A1040 | Utility balances & summaries |  | 26d | 2024-02-01 | 2024-03-10 | A1030 SS+8d | 100% |
| A1050 | Plot plan — concept |  | 17d | 2024-02-11 | 2024-03-05 | A1040 SS+5d, A1020 SS, A1000 | 100% |
| A1060 | HAZID workshop |  | 26d | 2024-02-12 | 2024-03-19 | A1050 SS+9d | 100% |
| A1070 | Long-lead equipment list |  | 19d | 2024-02-25 | 2024-03-21 | A1060 SS+5d, A1040 SS, A1020, A1000 | 100% |
| A1080 | Cost estimate — Class 3 |  | 11d | 2024-03-02 | 2024-03-18 | A1070 SS+9d | 100% |
| A1090 | Execution plan & contracting strategy |  | 25d | 2024-03-10 | 2024-04-13 | A1080 SS+3d, A1060 SS, A1040, A1020 | 100% |
| A1100 | Constructability review |  | 22d | 2024-03-11 | 2024-04-10 | A1090 SS+3d | 100% |
| A1110 | FID support dossier |  | 20d | 2024-03-17 | 2024-04-13 | A1100 SS+9d, A1080 SS, A1060 SS, A1040 | 100% |
| A1120 | Concept screening & selection study — U-21 Inlet & Metering |  | 20d | 2024-03-23 | 2024-04-19 | A1110 SS+3d | 100% |
| A1130 | Design basis memorandum — U-21 Inlet & Metering |  | 20d | 2024-04-02 | 2024-04-30 | A1120 SS+8d, A1100 SS, A1080, A1060 | 100% |
| A1140 | Process simulations & H&MB — U-21 Inlet & Metering |  | 25d | 2024-04-09 | 2024-05-14 | A1130 SS+9d | 100% |
| A1150 | PFD package — IFR — U-21 Inlet & Metering |  | 25d | 2024-04-12 | 2024-05-17 | A1140 SS+6d, A1120 SS, A1100, A1080 | 100% |
| A1160 | Utility balances & summaries — U-21 Inlet & Metering |  | 12d | 2024-04-24 | 2024-05-12 | A1150 SS+9d | 100% |
| A1170 | Plot plan — concept — U-21 Inlet & Metering |  | 11d | 2024-04-24 | 2024-05-09 | A1160 SS+6d, A1140 SS, A1120, A1100 | 100% |
| A1180 | HAZID workshop — U-21 Inlet & Metering |  | 14d | 2024-04-29 | 2024-05-17 | A1170 SS+10d | 100% |
| A1190 | Long-lead equipment list — U-21 Inlet & Metering |  | 16d | 2024-05-07 | 2024-05-29 | A1180 SS+7d | 100% |
| A1200 | Cost estimate — Class 3 — U-21 Inlet & Metering |  | 20d | 2024-05-18 | 2024-06-16 | A1190 SS+9d, A1180, A1160 | 100% |
| A1210 | Execution plan & contracting strategy — U-21 Inlet & Metering |  | 21d | 2024-05-23 | 2024-06-21 | A1200 SS+3d | 100% |
| A1230 | FID support dossier — U-21 Inlet & Metering |  | 25d | 2024-05-25 | 2024-06-28 | A1220 SS+4d, A1270 SS, A1190 SS, A1180 | 100% |
| A1220 | Constructability review — U-21 Inlet & Metering |  | 12d | 2024-05-27 | 2024-06-12 | A1210 SS+10d, A1270 SS, A1190 SS | 100% |
| A1240 | M1 — FEED complete & FID | milestone | 0d | 2024-06-28 | 2024-06-28 | A1230 FF | 100% |

| ID | Activity | Duration | Start | Finish | Predecessors | Complete |
| --- | --- | --- | --- | --- | --- | --- |
|  | **Process & Systems Engineering** |  | 2024-05-06 | 2024-11-29 |  |  |
| A1250 | P&ID package 1 — IFR | 23d | 2024-05-06 | 2024-06-06 | A1000 SS+69d, A1160 SS, A1140 SS, A1120 | 100% |
| A1260 | P&ID package 2 — IFR | 17d | 2024-05-09 | 2024-06-03 | A1250 SS+3d, A1180 SS, A1160 SS, A1140 SS | 100% |
| A1270 | P&ID package 1 — IFD | 12d | 2024-05-15 | 2024-06-02 | A1260 SS+5d | 100% |
| A1280 | P&ID package 2 — IFD | 27d | 2024-05-25 | 2024-07-02 | A1270 SS+6d | 100% |
| A1290 | Line designation tables | 16d | 2024-05-30 | 2024-06-22 | A1280 SS+8d | 100% |
| A1300 | Relief load summary & flare study | 11d | 2024-06-06 | 2024-06-21 | A1290 SS+9d | 100% |
| A1310 | HAZOP workshops | 24d | 2024-06-12 | 2024-07-16 | A1300 SS+4d, A1290 SS, A1280 SS, A1210 SS | 100% |
| A1320 | HAZOP action close-out | 19d | 2024-06-21 | 2024-07-18 | A1310 SS+9d, A1300, A1290 SS, A1280 SS | 100% |
| A1330 | SIL determination | 18d | 2024-06-26 | 2024-07-22 | A1320 SS+6d, A2730 SS, A1300, A1290 | 100% |
| A1340 | Process datasheets | 11d | 2024-06-30 | 2024-07-15 | A1330 SS+5d, A2740 SS, A2730 SS, A1300 | 100% |
| A1350 | Operating philosophy | 15d | 2024-07-08 | 2024-07-29 | A1340 SS+10d, A1550 SS, A1240, A2740 SS | 100% |
| A1360 | Cause & effect matrices | 21d | 2024-07-17 | 2024-08-15 | A1350 SS+3d | 100% |
| A1380 | P&ID package 2 — IFR — U-21 Inlet & Metering | 12d | 2024-07-24 | 2024-08-10 | A1370 SS+9d | 100% |
| A1370 | P&ID package 1 — IFR — U-21 Inlet & Metering | 21d | 2024-07-25 | 2024-08-23 | A1360 SS+7d, A1580 SS, A2750 SS | 100% |
| A1390 | P&ID package 1 — IFD — U-21 Inlet & Metering | 20d | 2024-08-04 | 2024-08-30 | A1380 SS+9d | 100% |
| A1400 | P&ID package 2 — IFD — U-21 Inlet & Metering | 25d | 2024-08-10 | 2024-09-14 | A1390 SS+5d, A1600 SS, A2770 SS | 100% |
| A1410 | Line designation tables — U-21 Inlet & Metering | 19d | 2024-08-12 | 2024-09-06 | A1400 SS+3d, A2780 SS, A1390 SS, A1600 SS | 100% |
| A1420 | Relief load summary & flare study — U-21 Inlet & Metering | 17d | 2024-08-25 | 2024-09-17 | A1410 SS+8d, A1900 SS, A3170 SS, A2790 SS | 100% |
| A1430 | HAZOP workshops — U-21 Inlet & Metering | 12d | 2024-08-28 | 2024-09-13 | A1420 SS+3d, A1910 SS, A1900 SS, A3170 SS | 100% |
| A1440 | HAZOP action close-out — U-21 Inlet & Metering | 18d | 2024-09-03 | 2024-09-28 | A1430 SS+10d | 100% |
| A1450 | SIL determination — U-21 Inlet & Metering | 26d | 2024-09-05 | 2024-10-12 | A1440 SS+10d, A1920 SS, A1630 SS, A2800 SS | 100% |
| A1460 | Process datasheets — U-21 Inlet & Metering | 21d | 2024-09-17 | 2024-10-16 | A1450 SS+7d, A1930 SS, A2820 SS, A3180 SS | 100% |
| A1470 | Operating philosophy — U-21 Inlet & Metering | 20d | 2024-09-22 | 2024-10-19 | A1460 SS+4d, A1650 SS, A1930 SS, A2820 SS | 100% |
| A1480 | Cause & effect matrices — U-21 Inlet & Metering | 12d | 2024-09-25 | 2024-10-12 | A1470 SS+5d, A1940 SS, A3190 SS, A1650 SS | 100% |
| A1490 | P&ID package 1 — IFR — U-22 Compression | 22d | 2024-10-08 | 2024-11-07 | A1480 SS+4d | 100% |
| A1500 | P&ID package 2 — IFR — U-22 Compression | 15d | 2024-10-13 | 2024-11-03 | A1490 SS+8d, A2840 SS, A1680 SS | 100% |
| A1510 | P&ID package 1 — IFD — U-22 Compression | 15d | 2024-10-20 | 2024-11-10 | A1500 SS+3d | 100% |
| A1520 | P&ID package 2 — IFD — U-22 Compression | 23d | 2024-10-23 | 2024-11-25 | A1510 SS+8d, A3210 SS, A1700 SS, A2390 SS | 100% |
| A1530 | Line designation tables — U-22 Compression | 25d | 2024-10-27 | 2024-11-29 | A1520 SS+10d, A1710 SS, A1510 SS, A3210 SS | 100% |
| A1540 | Relief load summary & flare study — U-22 Compression | 15d | 2024-11-09 | 2024-11-29 | A1530 SS+3d | 100% |

| ID | Activity | Duration | Start | Finish | Predecessors | Complete |
| --- | --- | --- | --- | --- | --- | --- |
|  | **Detail Eng — Civil & Structural** |  | 2024-07-01 | 2025-03-14 |  |  |
| A1550 | Geotechnical investigation & report | 16d | 2024-07-01 | 2024-07-23 | A1240 | 100% |
| A1560 | Civil design basis & specs | 17d | 2024-07-05 | 2024-07-30 | A1550 SS+4d | 100% |
| A1570 | Foundation design — static equipment | 15d | 2024-07-17 | 2024-08-07 | A1560 SS+3d, A2750 SS, A1550 SS | 100% |
| A1580 | Foundation design — rotating equipment | 15d | 2024-07-19 | 2024-08-11 | A1570 SS+3d | 100% |
| A1590 | Piling layout & schedule — AFC | 11d | 2024-08-01 | 2024-08-16 | A1580 SS+9d, A1380 SS, A1360 SS | 100% |
| A1600 | Structural steel design | 21d | 2024-08-01 | 2024-09-01 | A1590 SS+4d | 100% |
| A1610 | Pipe-rack design & shop dwgs | 16d | 2024-08-15 | 2024-09-06 | A1600 SS+6d, A2790 SS, A2780 SS, A1390 SS | 100% |
| A1620 | Paving, roads & drainage — AFC | 19d | 2024-08-19 | 2024-09-13 | A1610 SS+8d, A3170 SS, A2790 SS, A2780 SS | 100% |
| A1630 | Buildings — structural & finishes | 22d | 2024-08-28 | 2024-09-28 | A1620 SS+6d | 100% |
| A1640 | Geotechnical investigation & report — U-21 Inlet & Metering | 20d | 2024-08-31 | 2024-09-29 | A1630 SS+9d, A2800 SS, A1910 SS, A1900 SS | 100% |
| A1660 | Foundation design — static equipment — U-21 Inlet & Metering | 26d | 2024-09-12 | 2024-10-18 | A1650 SS+7d, A3180 SS, A1440 SS, A1920 SS | 100% |
| A1650 | Civil design basis & specs — U-21 Inlet & Metering | 16d | 2024-09-13 | 2024-10-07 | A1640 SS+3d | 100% |
| A1670 | Foundation design — rotating equipment — U-21 Inlet & Metering | 26d | 2024-09-24 | 2024-10-30 | A1660 SS+9d | 100% |
| A1680 | Piling layout & schedule — AFC — U-21 Inlet & Metering | 25d | 2024-10-03 | 2024-11-07 | A1670 SS+3d | 100% |
| A1690 | Structural steel design — U-21 Inlet & Metering | 18d | 2024-10-06 | 2024-10-30 | A1680 SS+3d, A2830 SS, A1670 SS, A1940 SS | 100% |
| A1700 | Pipe-rack design & shop dwgs — U-21 Inlet & Metering | 23d | 2024-10-14 | 2024-11-14 | A1690 SS+7d | 100% |
| A1710 | Paving, roads & drainage — AFC — U-21 Inlet & Metering | 21d | 2024-10-24 | 2024-11-24 | A1700 SS+8d | 100% |
| A1720 | Buildings — structural & finishes — U-21 Inlet & Metering | 24d | 2024-10-25 | 2024-11-28 | A1710 SS+7d, A1510 SS, A3210 SS, A1700 SS | 100% |
| A1730 | Geotechnical investigation & report — U-22 Compression | 14d | 2024-11-03 | 2024-11-21 | A1720 SS+4d, A2860 SS, A2400 SS, A1710 SS | 100% |
| A1740 | Civil design basis & specs — U-22 Compression | 13d | 2024-11-08 | 2024-11-27 | A1730 SS+8d, A1990 SS, A3220 SS, A2860 SS | 100% |
| A1750 | Foundation design — static equipment — U-22 Compression | 12d | 2024-11-15 | 2024-12-03 | A1740 SS+8d, A1540 SS, A2410 SS, A1990 SS | 100% |
| A1760 | Foundation design — rotating equipment — U-22 Compression | 14d | 2024-11-23 | 2024-12-12 | A1750 SS+3d, A3950 SS, A2420 SS, A2880 SS | 100% |
| A1770 | Piling layout & schedule — AFC — U-22 Compression | 25d | 2024-11-30 | 2025-01-04 | A1760 SS+8d | 100% |
| A1780 | Structural steel design — U-22 Compression | 18d | 2024-12-09 | 2025-01-02 | A1770 SS+8d | 100% |
| A1790 | Pipe-rack design & shop dwgs — U-22 Compression | 22d | 2024-12-16 | 2025-01-15 | A1780 SS+9d, A2900 SS | 100% |
| A1800 | Paving, roads & drainage — AFC — U-22 Compression | 17d | 2024-12-25 | 2025-01-18 | A1790 SS+3d | 100% |
| A1810 | Buildings — structural & finishes — U-22 Compression | 10d | 2024-12-27 | 2025-01-11 | A1800 SS+5d | 100% |
| A1820 | Geotechnical investigation & report — U-23 Dehydration | 13d | 2025-01-07 | 2025-01-26 | A1810 SS+8d | 100% |
| A1830 | Civil design basis & specs — U-23 Dehydration | 16d | 2025-01-16 | 2025-02-09 | A1820 SS+3d | 100% |
| A1840 | Foundation design — static equipment — U-23 Dehydration | 19d | 2025-01-19 | 2025-02-13 | A1830 SS+8d | 100% |
| A1850 | Foundation design — rotating equipment — U-23 Dehydration | 21d | 2025-01-25 | 2025-02-24 | A1840 SS+9d, A4080 SS | 100% |
| A1860 | Piling layout & schedule — AFC — U-23 Dehydration | 26d | 2025-02-03 | 2025-03-11 | A1850 SS+3d | 100% |
| A1870 | Structural steel design — U-23 Dehydration | 11d | 2025-02-13 | 2025-03-02 | A1860 SS+10d, A2090 SS, A4190 SS | 100% |
| A1880 | Pipe-rack design & shop dwgs — U-23 Dehydration | 20d | 2025-02-16 | 2025-03-14 | A1870 SS+8d, A3480 SS, A2090 SS | 100% |

| ID | Activity | Type | Duration | Start | Finish | Predecessors | Complete | Remaining |
| --- | --- | --- | --- | --- | --- | --- | --- | --- |
|  | **Detail Eng — Mech. & Piping** |  |  | 2024-08-05 | 2025-10-24 |  |  |  |
| A1890 | Equipment datasheets & requisitions |  | 17d | 2024-08-05 | 2024-08-28 | A1390 SS, A1600 SS, A2770 SS, A1380 SS | 100% |  |
| A1900 | Vendor document review — cycle 1 |  | 21d | 2024-08-15 | 2024-09-15 | A1890 SS+10d | 100% |  |
| A1910 | Vendor document review — cycle 2 |  | 12d | 2024-08-20 | 2024-09-05 | A1900 SS+7d | 100% |  |
| A1920 | 3D model — 30% review & actions |  | 16d | 2024-08-31 | 2024-09-23 | A1910 SS+4d | 100% |  |
| A1930 | 3D model — 60% review & actions |  | 13d | 2024-09-12 | 2024-10-01 | A1920 SS+5d | 100% |  |
| A1940 | 3D model — 90% review & actions |  | 19d | 2024-09-22 | 2024-10-17 | A1930 SS+4d | 100% |  |
| A1950 | Piping material classes & specs |  | 19d | 2024-09-30 | 2024-10-25 | A1940 SS+3d, A1670 SS, A3190 SS | 100% |  |
| A1960 | Piping isometrics |  | 22d | 2024-10-10 | 2024-11-11 | A1950 SS+9d, A2840 SS, A1680 SS, A2830 SS | 100% |  |
| A1970 | Pipe stress analysis — critical lines |  | 25d | 2024-10-15 | 2024-11-19 | A1960 SS+9d, A1540 SS+29d, A2390 SS, A1490 SS, A2840 SS | 100% |  |
| A1980 | Piping MTO & bulk requisitions |  | 22d | 2024-10-30 | 2024-11-29 | A1970 SS+6d, A2400 SS, A1710 SS, A1510 SS | 100% |  |
| A1990 | Nozzle orientation & GA reviews |  | 26d | 2024-11-03 | 2024-12-09 | A1980 SS+7d | 100% |  |
| A2000 | Tie-in schedule — AFC |  | 15d | 2024-11-20 | 2024-12-11 | A1990 SS+8d, A2880 SS, A3930 SS, A1540 SS | 100% |  |
| A2010 | Equipment datasheets & requisitions — U-21 Inlet & Metering |  | 27d | 2024-11-24 | 2024-12-31 | A2000 SS+9d | 100% |  |
| A2020 | Vendor document review — cycle 1 — U-21 Inlet & Metering |  | 10d | 2024-12-06 | 2024-12-22 | A2010 SS+8d, A2890 SS, A1770 SS | 100% |  |
| A2030 | Vendor document review — cycle 2 — U-21 Inlet & Metering |  | 11d | 2024-12-18 | 2025-01-02 | A2020 SS+4d | 100% |  |
| A2040 | 3D model — 30% review & actions — U-21 Inlet & Metering |  | 13d | 2024-12-24 | 2025-01-10 | A2030 SS+10d, A4010 SS | 100% |  |
| A2050 | 3D model — 60% review & actions — U-21 Inlet & Metering |  | 22d | 2024-12-31 | 2025-01-30 | A2040 SS+7d | 100% |  |
| A2060 | 3D model — 90% review & actions — U-21 Inlet & Metering |  | 20d | 2025-01-13 | 2025-02-10 | A2050 SS+4d | 100% |  |
| A2070 | Piping material classes & specs — U-21 Inlet & Metering |  | 20d | 2025-01-17 | 2025-02-16 | A2060 SS+7d, A4070 SS | 100% |  |
| A2080 | Piping isometrics — U-21 Inlet & Metering |  | 22d | 2025-01-31 | 2025-03-04 | A2070 SS+8d | 100% |  |
| A2090 | Pipe stress analysis — critical lines — U-21 Inlet & Metering |  | 27d | 2025-02-12 | 2025-03-21 | A2080 SS+4d | 100% |  |
| A2100 | Piping MTO & bulk requisitions — U-21 Inlet & Metering |  | 13d | 2025-02-21 | 2025-03-12 | A2090 SS+10d, A4230 SS, A4210 SS | 100% |  |
| A2110 | Nozzle orientation & GA reviews — U-21 Inlet & Metering |  | 25d | 2025-02-24 | 2025-03-31 | A2100 SS+6d, A4160 SS, A4140 SS | 100% |  |
| A2120 | Tie-in schedule — AFC — U-21 Inlet & Metering |  | 11d | 2025-03-06 | 2025-03-21 | A2110 SS+5d, A4170 SS, A4250 SS, A3500 SS | 100% |  |
| A2130 | Equipment datasheets & requisitions — U-22 Compression |  | 27d | 2025-03-18 | 2025-04-24 | A2120 SS+5d | 100% |  |
| A2140 | Vendor document review — cycle 1 — U-22 Compression |  | 16d | 2025-03-26 | 2025-04-17 | A2130 SS+6d, A3000 SS, A3310 SS | 100% |  |
| A2150 | Vendor document review — cycle 2 — U-22 Compression |  | 11d | 2025-04-03 | 2025-04-19 | A2140 SS+6d | 100% |  |
| A2160 | 3D model — 30% review & actions — U-22 Compression |  | 24d | 2025-04-13 | 2025-05-15 | A2150 SS+9d | 100% |  |
| A2170 | 3D model — 60% review & actions — U-22 Compression |  | 14d | 2025-04-28 | 2025-05-17 | A2160 SS+5d | 100% |  |
| A2180 | 3D model — 90% review & actions — U-22 Compression |  | 14d | 2025-05-01 | 2025-05-21 | A2170 SS+9d | 100% |  |
| A2190 | Piping material classes & specs — U-22 Compression |  | 15d | 2025-05-10 | 2025-05-31 | A2180 SS+10d, A4430 SS, A3600 SS | 100% |  |
| A2200 | Piping isometrics — U-22 Compression |  | 18d | 2025-05-20 | 2025-06-13 | A2190 SS+9d, A4450 SS, A3610 SS | 100% |  |
| A2210 | Pipe stress analysis — critical lines — U-22 Compression |  | 17d | 2025-06-01 | 2025-06-24 | A2200 SS+7d | 100% |  |
| A2220 | Piping MTO & bulk requisitions — U-22 Compression |  | 15d | 2025-06-14 | 2025-07-04 | A2210 SS+8d, A3650 SS, A3360 SS | 100% |  |
| A2230 | Nozzle orientation & GA reviews — U-22 Compression |  | 24d | 2025-06-16 | 2025-07-19 | A2220 SS+7d, A4760 SS, A3650 SS | 100% |  |
| A2240 | Tie-in schedule — AFC — U-22 Compression |  | 24d | 2025-06-24 | 2025-07-28 | A2230 SS+3d | 100% |  |
| A2350 | M2 — 3D model 90% & AFC issue | milestone | 0d | 2025-06-30 | 2025-06-30 | A1940 FF | 100% |  |
| A2250 | Equipment datasheets & requisitions — U-23 Dehydration |  | 25d | 2025-07-05 | 2025-08-08 | A2240 SS+10d, A2350, A2600 SS | 100% |  |
| A2260 | Vendor document review — cycle 1 — U-23 Dehydration |  | 28d | 2025-07-13 | 2025-08-20 | A2250 SS+5d, A4830 SS, A3380 SS | 100% |  |
| A2270 | Vendor document review — cycle 2 — U-23 Dehydration |  | 21d | 2025-07-28 | 2025-08-26 | A2260 SS+5d | 100% |  |
| A2280 | 3D model — 30% review & actions — U-23 Dehydration |  | 19d | 2025-08-04 | 2025-08-29 | A2270 SS+4d | 100% |  |
| A2290 | 3D model — 60% review & actions — U-23 Dehydration |  | 24d | 2025-08-18 | 2025-09-21 | A2280 SS+3d | 100% |  |
| A2300 | 3D model — 90% review & actions — U-23 Dehydration |  | 16d | 2025-08-25 | 2025-09-16 | A2290 SS+4d | 100% |  |
| A2310 | Piping material classes & specs — U-23 Dehydration |  | 16d | 2025-09-04 | 2025-09-27 | A2300 SS+8d | 100% |  |
| A2320 | Piping isometrics — U-23 Dehydration |  | 25d | 2025-09-13 | 2025-10-18 | A2310 SS+8d, A3790 SS, A4990 SS |  | 25d |
| A2330 | Pipe stress analysis — critical lines — U-23 Dehydration |  | 28d | 2025-09-16 | 2025-10-24 | A2320 SS+6d |  | 28d |
| A2340 | Piping MTO & bulk requisitions — U-23 Dehydration |  | 25d | 2025-09-21 | 2025-10-24 | A2330 SS+4d |  | 25d |

| ID | Activity | Duration | Start | Finish | Predecessors | Complete | Remaining |
| --- | --- | --- | --- | --- | --- | --- | --- |
|  | **Detail Eng — Elec. & Instr.** |  | 2024-09-02 | 2025-12-05 |  |  |  |
| A2360 | Electrical load list & studies | 14d | 2024-09-02 | 2024-09-20 | A1250 SS+51d, A1630 SS, A2800 SS, A1910 SS | 100% |  |
| A2370 | Single-line diagrams — AFC | 16d | 2024-09-12 | 2024-10-04 | A2360 SS+6d, A2820 SS, A3180 SS, A1440 SS | 100% |  |
| A2380 | Substation & equipment-room layouts | 24d | 2024-09-23 | 2024-10-26 | A2370 SS+6d, A3190 SS, A1650 SS, A1930 SS | 100% |  |
| A2390 | Cable schedules & sizing | 25d | 2024-10-12 | 2024-11-16 | A2380 SS+9d | 100% |  |
| A2400 | Cable routing & tray layouts | 10d | 2024-10-25 | 2024-11-09 | A2390 SS+5d | 100% |  |
| A2410 | Earthing & lightning protection | 23d | 2024-11-07 | 2024-12-10 | A2400 SS+5d | 100% |  |
| A2420 | Instrument index & I/O list | 18d | 2024-11-19 | 2024-12-15 | A2410 SS+6d | 100% |  |
| A2430 | Instrument datasheets | 11d | 2024-11-27 | 2024-12-12 | A2420 SS+8d, A3960 SS, A3950 SS | 100% |  |
| A2440 | DCS/SIS architecture & specs | 16d | 2024-12-12 | 2025-01-05 | A2430 SS+8d, A3240 SS, A3990 SS | 100% |  |
| A2450 | Control narratives | 25d | 2024-12-25 | 2025-01-29 | A2440 SS+3d, A3250 SS, A2030 SS | 100% |  |
| A2460 | Loop diagrams | 20d | 2025-01-03 | 2025-01-31 | A2450 SS+9d, A4040 SS, A1810 SS | 100% |  |
| A2470 | Telecoms & CCTV design | 12d | 2025-01-15 | 2025-02-01 | A2460 SS+10d, A2060 SS, A1820 SS | 100% |  |
| A2480 | Electrical load list & studies — U-21 Inlet & Metering | 25d | 2025-02-02 | 2025-03-08 | A2470 SS+8d, A2080 SS, A4100 SS | 100% |  |
| A2490 | Single-line diagrams — AFC — U-21 Inlet & Metering | 15d | 2025-02-07 | 2025-03-02 | A2480 SS+5d, A3280 SS, A1860 SS | 100% |  |
| A2500 | Substation & equipment-room layouts — U-21 Inlet & Metering | 26d | 2025-02-27 | 2025-04-05 | A2490 SS+10d, A2970 SS, A4160 SS | 100% |  |
| A2510 | Cable schedules & sizing — U-21 Inlet & Metering | 17d | 2025-03-09 | 2025-04-01 | A2500 SS+4d | 100% |  |
| A2520 | Cable routing & tray layouts — U-21 Inlet & Metering | 12d | 2025-03-19 | 2025-04-05 | A2510 SS+7d, A3530 SS, A2990 SS | 100% |  |
| A2530 | Earthing & lightning protection — U-21 Inlet & Metering | 26d | 2025-04-03 | 2025-05-11 | A2520 SS+6d, A4320 SS, A4330 SS | 100% |  |
| A2540 | Instrument index & I/O list — U-21 Inlet & Metering | 26d | 2025-04-10 | 2025-05-16 | A2530 SS+9d | 100% |  |
| A2550 | Instrument datasheets — U-21 Inlet & Metering | 26d | 2025-04-24 | 2025-06-01 | A2540 SS+9d | 100% |  |
| A2560 | DCS/SIS architecture & specs — U-21 Inlet & Metering | 18d | 2025-05-10 | 2025-06-04 | A2550 SS+7d | 100% |  |
| A2570 | Control narratives — U-21 Inlet & Metering | 15d | 2025-05-18 | 2025-06-06 | A2560 SS+10d | 100% |  |
| A2580 | Loop diagrams — U-21 Inlet & Metering | 18d | 2025-05-31 | 2025-06-25 | A2570 SS+5d, A4490 SS, A3060 SS | 100% |  |
| A2590 | Telecoms & CCTV design — U-21 Inlet & Metering | 26d | 2025-06-19 | 2025-07-26 | A2580 SS+8d, A3080 SS, A4780 SS | 100% |  |
| A2600 | Electrical load list & studies — U-22 Compression | 18d | 2025-06-28 | 2025-07-23 | A2590 SS+7d | 100% |  |
| A2610 | Single-line diagrams — AFC — U-22 Compression | 17d | 2025-07-13 | 2025-08-05 | A2600 SS+4d | 100% |  |
| A2620 | Substation & equipment-room layouts — U-22 Compression | 12d | 2025-07-22 | 2025-08-07 | A2610 SS+6d | 100% |  |
| A2630 | Cable schedules & sizing — U-22 Compression | 14d | 2025-08-03 | 2025-08-21 | A2620 SS+4d, A3730 SS, A2270 SS | 100% |  |
| A2640 | Cable routing & tray layouts — U-22 Compression | 15d | 2025-08-15 | 2025-09-06 | A2630 SS+4d, A4730 SS, A4920 SS, A4720 SS | 100% |  |
| A2650 | Earthing & lightning protection — U-22 Compression | 15d | 2025-08-24 | 2025-09-12 | A2640 SS+9d | 100% |  |
| A2660 | Instrument index & I/O list — U-22 Compression | 15d | 2025-09-06 | 2025-09-26 | A2650 SS+10d, A3780 SS, A5420 SS | 100% |  |
| A2670 | Instrument datasheets — U-22 Compression | 25d | 2025-09-21 | 2025-10-26 | A2660 SS+6d, A5030 SS, A5020 SS |  | 25d |
| A2680 | DCS/SIS architecture & specs — U-22 Compression | 23d | 2025-10-07 | 2025-11-09 | A2670 SS+5d, A5970 SS, A5060 SS |  |  |
| A2690 | Control narratives — U-22 Compression | 24d | 2025-10-21 | 2025-11-24 | A2680 SS+9d |  |  |
| A2700 | Loop diagrams — U-22 Compression | 21d | 2025-10-30 | 2025-11-29 | A2690 SS+7d, A6040 SS, A5120 SS |  |  |
| A2710 | Telecoms & CCTV design — U-22 Compression | 25d | 2025-11-02 | 2025-12-05 | A2700 SS+9d, A6050 SS, A6040 SS |  |  |

| ID | Activity | Duration | Start | Finish | Predecessors |
| --- | --- | --- | --- | --- | --- |
|  | **Pre-Commissioning** |  | 2026-07-06 | 2027-04-30 |  |
|  | **Mech. Completion & Punch-list** |  | 2026-07-06 | 2026-10-16 |  |
| A8080 | System walkdowns | 19d | 2026-07-06 | 2026-08-01 | A7520 FF, A6800 SS, A7890 SS |
| A8090 | Punch-listing & categorisation | 26d | 2026-07-06 | 2026-08-11 | A8080 SS+7d |
| A8110 | MC certificates | 17d | 2026-07-11 | 2026-08-04 | A8100 SS+3d, A7450 SS, A8090 SS |
| A8100 | Punch clearance — cat A | 28d | 2026-07-12 | 2026-08-19 | A8090 SS+4d, A7910 SS, A7450 SS |
| A8120 | System walkdowns — U-21 Inlet & Metering | 16d | 2026-07-21 | 2026-08-12 | A8110 SS+5d, A7470 SS, A6840 SS |
| A8130 | Punch-listing & categorisation — U-21 Inlet & Metering | 22d | 2026-07-23 | 2026-08-24 | A8120 SS+9d, A7930 SS, A7470 SS |
| A8150 | MC certificates — U-21 Inlet & Metering | 25d | 2026-07-25 | 2026-08-29 | A8140 SS+10d, A7480 SS, A7930 SS |
| A8140 | Punch clearance — cat A — U-21 Inlet & Metering | 18d | 2026-07-28 | 2026-08-23 | A8130 SS+7d |
| A8170 | Punch-listing & categorisation — U-22 Compression | 11d | 2026-07-30 | 2026-08-14 | A8160 SS+3d, A8140 SS, A6860 SS |
| A8160 | System walkdowns — U-22 Compression | 23d | 2026-08-03 | 2026-09-03 | A8150 SS+8d, A7960 SS, A6880 SS |
| A8180 | Punch clearance — cat A — U-22 Compression | 13d | 2026-08-05 | 2026-08-24 | A8170 SS+6d, A6900 SS, A7960 SS |
| A8190 | MC certificates — U-22 Compression | 15d | 2026-08-09 | 2026-08-28 | A8180 SS+9d, A6910 SS, A7510 SS |
| A8200 | System walkdowns — U-23 Dehydration | 25d | 2026-08-16 | 2026-09-19 | A8190 SS+8d, A6920 SS, A7980 SS |
| A8210 | Punch-listing & categorisation — U-23 Dehydration | 22d | 2026-08-19 | 2026-09-20 | A8200 SS+5d, A6960 SS, A7520 SS |
| A8220 | Punch clearance — cat A — U-23 Dehydration | 21d | 2026-08-21 | 2026-09-21 | A8210 SS+6d, A6930 SS, A6960 SS |
| A8250 | Punch-listing & categorisation — U-24 Fractionation | 15d | 2026-08-24 | 2026-09-14 | A8240 SS+8d, A8010 SS, A6930 SS |
| A8230 | MC certificates — U-23 Dehydration | 27d | 2026-08-26 | 2026-10-02 | A8220 SS+9d |
| A8240 | System walkdowns — U-24 Fractionation | 16d | 2026-08-26 | 2026-09-17 | A8230 SS+5d, A6950 SS, A8010 SS |
| A8260 | Punch clearance — cat A — U-24 Fractionation | 14d | 2026-08-27 | 2026-09-16 | A8250 SS+5d |
| A8280 | System walkdowns — U-25 Utilities | 16d | 2026-09-04 | 2026-09-28 | A8270 SS+6d, A8260 SS, A8230 SS |
| A8270 | MC certificates — U-24 Fractionation | 27d | 2026-09-06 | 2026-10-13 | A8260 SS+8d, A8030 SS |
| A8290 | Punch-listing & categorisation — U-25 Utilities | 15d | 2026-09-07 | 2026-09-28 | A8280 SS+5d |
| A8300 | Punch clearance — cat A — U-25 Utilities | 25d | 2026-09-11 | 2026-10-16 | A8290 SS+4d |
| A8320 | System walkdowns — U-26 Offsites & Flare | 25d | 2026-09-12 | 2026-10-16 | A8310 SS+10d |
| A8310 | MC certificates — U-25 Utilities | 22d | 2026-09-16 | 2026-10-16 | A8300 SS+10d, A8360 SS |
| A8330 | Punch-listing & categorisation — U-26 Offsites & Flare | 16d | 2026-09-24 | 2026-10-16 | A8320 SS+6d, A6960 FF+20d, A8060 SS, A8380 SS |

| ID | Activity | Duration | Start | Finish | Predecessors |
| --- | --- | --- | --- | --- | --- |
|  | **Hydrotesting & Loop Checks** |  | 2026-09-07 | 2026-12-31 |  |
| A8340 | Test pack preparation | 14d | 2026-09-07 | 2026-09-25 | A8080 SS+44d, A8040 SS, A8030 SS |
| A8350 | Hydrotest | 17d | 2026-09-11 | 2026-10-06 | A8340 SS+7d, A8290 SS, A8040 SS |
| A8360 | Flushing & drying | 17d | 2026-09-11 | 2026-10-06 | A8350 SS+8d |
| A8370 | Reinstatement | 16d | 2026-09-13 | 2026-10-05 | A8360 SS+3d, A8300 SS |
| A8380 | Loop check | 18d | 2026-09-16 | 2026-10-12 | A8370 SS+5d, A7800 SS+25d |
| A8390 | Point-to-point tests | 12d | 2026-09-17 | 2026-10-05 | A8380 SS+5d, A8050 SS, A8320 SS |
| A8400 | Test pack preparation — U-21 Inlet & Metering | 17d | 2026-09-23 | 2026-10-18 | A8390 SS+9d, A8380 SS, A8050 SS |
| A8410 | Hydrotest — U-21 Inlet & Metering | 11d | 2026-09-23 | 2026-10-08 | A8400 SS+10d |
| A8430 | Reinstatement — U-21 Inlet & Metering | 22d | 2026-10-01 | 2026-11-02 | A8420 SS+9d, A8330 SS |
| A8440 | Loop check — U-21 Inlet & Metering | 19d | 2026-10-02 | 2026-10-29 | A8430 SS+8d, A8410 SS, A8060 SS |
| A8420 | Flushing & drying — U-21 Inlet & Metering | 14d | 2026-10-03 | 2026-10-22 | A8410 SS+10d |
| A8450 | Point-to-point tests — U-21 Inlet & Metering | 25d | 2026-10-10 | 2026-11-15 | A8440 SS+10d, A8430 SS, A8410 |
| A8460 | Test pack preparation — U-22 Compression | 28d | 2026-10-11 | 2026-11-18 | A8450 SS+4d |
| A8470 | Hydrotest — U-22 Compression | 12d | 2026-10-16 | 2026-11-03 | A8460 SS+10d, A8420 SS, A8430 SS |
| A8490 | Reinstatement — U-22 Compression | 12d | 2026-10-17 | 2026-11-03 | A8480 SS+5d |
| A8480 | Flushing & drying — U-22 Compression | 23d | 2026-10-20 | 2026-11-21 | A8470 SS+9d, A8460 SS, A8420 SS |
| A8510 | Point-to-point tests — U-22 Compression | 23d | 2026-10-20 | 2026-11-21 | A8500 SS+9d |
| A8500 | Loop check — U-22 Compression | 17d | 2026-10-22 | 2026-11-16 | A8490 SS+3d, A8460 SS |
| A8520 | Test pack preparation — U-23 Dehydration | 23d | 2026-10-27 | 2026-11-29 | A8510 SS+7d |
| A8540 | Flushing & drying — U-23 Dehydration | 24d | 2026-10-29 | 2026-12-02 | A8530 SS+9d, A8510 SS, A8490 SS |
| A8530 | Hydrotest — U-23 Dehydration | 26d | 2026-11-01 | 2026-12-07 | A8520 SS+3d |
| A8550 | Reinstatement — U-23 Dehydration | 24d | 2026-11-03 | 2026-12-07 | A8540 SS+4d, A8520 SS, A8510 SS |
| A8560 | Loop check — U-23 Dehydration | 26d | 2026-11-05 | 2026-12-13 | A8550 SS+8d |
| A8570 | Point-to-point tests — U-23 Dehydration | 11d | 2026-11-08 | 2026-11-23 | A8560 SS+6d, A8530 SS, A8520 SS |
| A8590 | Hydrotest — U-24 Fractionation | 17d | 2026-11-11 | 2026-12-04 | A8580 SS+5d |
| A8580 | Test pack preparation — U-24 Fractionation | 26d | 2026-11-16 | 2026-12-22 | A8570 SS+9d, A8560 SS, A8530 SS |
| A8600 | Flushing & drying — U-24 Fractionation | 22d | 2026-11-18 | 2026-12-18 | A8590 SS+9d |
| A8620 | Loop check — U-24 Fractionation | 12d | 2026-11-22 | 2026-12-08 | A8610 SS+4d, A8590 SS, A8560 SS |
| A8610 | Reinstatement — U-24 Fractionation | 18d | 2026-11-24 | 2026-12-20 | A8600 SS+6d |
| A8630 | Point-to-point tests — U-24 Fractionation | 15d | 2026-11-26 | 2026-12-17 | A8620 SS+5d, A8600 SS, A8590 SS |
| A8640 | Test pack preparation — U-25 Utilities | 18d | 2026-11-27 | 2026-12-23 | A8630 SS+9d |
| A8660 | Flushing & drying — U-25 Utilities | 19d | 2026-11-30 | 2026-12-27 | A8650 SS+10d, A8610 SS, A8600 SS |
| A8650 | Hydrotest — U-25 Utilities | 12d | 2026-12-02 | 2026-12-20 | A8640 SS+3d |
| A8670 | Reinstatement — U-25 Utilities | 20d | 2026-12-03 | 2026-12-31 | A8660 SS+10d, A8640 SS, A8610 SS |

| ID | Activity | Type | Duration | Start | Finish | Predecessors |
| --- | --- | --- | --- | --- | --- | --- |
|  | **System Commissioning & Start-up** |  |  | 2026-12-07 | 2027-04-30 |  |
| A8680 | Substation energization |  | 19d | 2026-12-07 | 2027-01-01 | A8670 FS-18d |
| A8690 | Utilities commissioning |  | 11d | 2026-12-08 | 2026-12-23 | A8680 SS+4d, A8650 SS, A8640 SS |
| A8710 | Control system integration tests |  | 15d | 2026-12-13 | 2027-01-02 | A8700 SS+3d, A8070 FF |
| A8700 | Nitrogen & instrument air commissioning |  | 19d | 2026-12-14 | 2027-01-09 | A8690 SS+7d, A8680 SS, A8650 SS |
| A8720 | Dynamic commissioning |  | 14d | 2026-12-23 | 2027-01-12 | A8710 SS+8d |
| A8730 | Operator training & procedures |  | 11d | 2026-12-23 | 2027-01-07 | A8720 SS+9d, A8710 SS, A8680 SS |
| A8740 | Performance test runs |  | 21d | 2026-12-24 | 2027-01-23 | A8730 SS+6d |
| A8750 | Punch-list close-out |  | 22d | 2026-12-28 | 2027-01-27 | A8740 SS+3d, A8720 SS, A8710 SS |
| A8760 | Substation energization — U-21 Inlet & Metering |  | 20d | 2026-12-31 | 2027-01-28 | A8750 SS+3d |
| A8770 | Utilities commissioning — U-21 Inlet & Metering |  | 21d | 2027-01-07 | 2027-02-07 | A8760 SS+7d, A8740 SS, A8720 SS |
| A8780 | Nitrogen & instrument air commissioning — U-21 Inlet & Metering |  | 25d | 2027-01-08 | 2027-02-12 | A8770 SS+5d |
| A8790 | Control system integration tests — U-21 Inlet & Metering |  | 27d | 2027-01-13 | 2027-02-20 | A8780 SS+3d, A8760 SS, A8740 SS |
| A8800 | Dynamic commissioning — U-21 Inlet & Metering |  | 12d | 2027-01-13 | 2027-01-30 | A8790 SS+5d |
| A8810 | Operator training & procedures — U-21 Inlet & Metering |  | 25d | 2027-01-15 | 2027-02-21 | A8800 SS+8d, A8780 SS, A8760 SS |
| A8820 | Performance test runs — U-21 Inlet & Metering |  | 15d | 2027-01-18 | 2027-02-08 | A8810 SS+8d |
| A8830 | Punch-list close-out — U-21 Inlet & Metering |  | 21d | 2027-01-24 | 2027-02-22 | A8820 SS+4d, A8800 SS, A8780 SS |
| A8840 | Substation energization — U-22 Compression |  | 27d | 2027-01-27 | 2027-03-05 | A8830 SS+5d |
| A8850 | Utilities commissioning — U-22 Compression |  | 19d | 2027-01-29 | 2027-02-25 | A8840 SS+7d, A8820 SS, A8800 SS |
| A8860 | Nitrogen & instrument air commissioning — U-22 Compression |  | 22d | 2027-02-01 | 2027-03-03 | A8850 SS+4d |
| A8870 | Control system integration tests — U-22 Compression |  | 26d | 2027-02-03 | 2027-03-11 | A8860 SS+5d, A8840 SS, A8820 SS |
| A8880 | Dynamic commissioning — U-22 Compression |  | 17d | 2027-02-04 | 2027-03-01 | A8870 SS+6d |
| A8890 | Operator training & procedures — U-22 Compression |  | 12d | 2027-02-08 | 2027-02-24 | A8880 SS+4d, A8860 SS, A8840 SS |
| A8900 | Performance test runs — U-22 Compression |  | 15d | 2027-02-11 | 2027-03-04 | A8890 SS+8d |
| A8910 | Punch-list close-out — U-22 Compression |  | 25d | 2027-02-12 | 2027-03-21 | A8900 SS+4d, A8880 SS, A8860 SS |
| A8920 | Substation energization — U-23 Dehydration |  | 18d | 2027-02-20 | 2027-03-17 | A8910 SS+7d |
| A8930 | Utilities commissioning — U-23 Dehydration |  | 11d | 2027-02-22 | 2027-03-09 | A8920 SS+5d, A8900 SS, A8880 SS |
| A8940 | Nitrogen & instrument air commissioning — U-23 Dehydration |  | 20d | 2027-02-28 | 2027-03-27 | A8930 SS+4d |
| A8960 | Dynamic commissioning — U-23 Dehydration |  | 20d | 2027-03-01 | 2027-03-29 | A8950 SS+10d, A8920 SS, A8900 SS |
| A8970 | Operator training & procedures — U-23 Dehydration |  | 23d | 2027-03-02 | 2027-04-02 | A8960 SS+8d |
| A8950 | Control system integration tests — U-23 Dehydration |  | 17d | 2027-03-03 | 2027-03-28 | A8940 SS+7d, A8920 SS |
| A8990 | Punch-list close-out — U-23 Dehydration |  | 27d | 2027-03-10 | 2027-04-17 | A8980 SS+6d |
| A9000 | Substation energization — U-24 Fractionation |  | 26d | 2027-03-11 | 2027-04-17 | A8990 SS+9d, A8970 SS, A8940 SS |
| A8980 | Performance test runs — U-23 Dehydration |  | 25d | 2027-03-12 | 2027-04-17 | A8970 SS+4d |
| A9010 | Utilities commissioning — U-24 Fractionation |  | 14d | 2027-03-19 | 2027-04-08 | A9000 SS+6d, A8990 SS, A8970 SS |
| A9020 | Nitrogen & instrument air commissioning — U-24 Fractionation |  | 18d | 2027-03-23 | 2027-04-18 | A9010 SS+6d |
| A9040 | Dynamic commissioning — U-24 Fractionation |  | 16d | 2027-03-25 | 2027-04-17 | A9030 SS+8d, A8980 SS, A8990 SS |
| A9050 | Operator training & procedures — U-24 Fractionation |  | 26d | 2027-03-25 | 2027-04-30 | A9040 SS+9d |
| A9030 | Control system integration tests — U-24 Fractionation |  | 10d | 2027-03-26 | 2027-04-10 | A9020 SS+8d, A8980 SS |
| A9070 | Punch-list close-out — U-24 Fractionation |  | 24d | 2027-03-29 | 2027-04-30 | A9060 SS+3d |
| A9060 | Performance test runs — U-24 Fractionation |  | 11d | 2027-04-03 | 2027-04-19 | A9050 SS+8d, A9020 SS |
| A9080 | M4 — Ready for operations | milestone | 0d | 2027-04-30 | 2027-04-30 | A9070 FF |

| ID | Activity | Duration | Start | Finish | Predecessors | Complete |
| --- | --- | --- | --- | --- | --- | --- |
|  | **Procurement** |  | 2024-06-03 | 2025-12-19 |  |  |
|  | **Rotating Eqpt — Compressors** |  | 2024-07-01 | 2025-09-19 |  |  |
| A3140 | Export compressor — RFQ & TBE | 14d | 2024-07-01 | 2024-07-21 | A1000 SS+102d, A1240, A2740 SS, A2730 SS | 100% |
| A3150 | Export compressor — PO & kick-off | 18d | 2024-07-19 | 2024-08-14 | A3140 SS+9d, A1360 SS, A2750 SS, A1560 SS | 100% |
| A3160 | Export compressor — fabrication | 11d | 2024-08-03 | 2024-08-19 | A3150 SS+5d, A2770 SS, A1380 SS, A1580 SS | 100% |
| A3170 | Refrigeration compressor — RFQ & TBE | 19d | 2024-08-14 | 2024-09-10 | A3160 SS+7d | 100% |
| A3180 | Refrigeration compressor — fabrication | 17d | 2024-09-05 | 2024-09-30 | A3170 SS+5d | 100% |
| A3190 | String test & FAT | 11d | 2024-09-17 | 2024-10-02 | A3180 SS+8d | 100% |
| A3200 | Auxiliary skids — fabrication | 15d | 2024-10-06 | 2024-10-26 | A3190 SS+9d, A1680 SS, A2830 SS, A1670 SS | 100% |
| A3210 | Transport & delivery to site | 24d | 2024-10-16 | 2024-11-19 | A3200 SS+10d | 100% |
| A3220 | Export compressor — RFQ & TBE — U-21 Inlet & Metering | 15d | 2024-11-01 | 2024-11-22 | A3210 SS+8d | 100% |
| A3230 | Export compressor — PO & kick-off — U-21 Inlet & Metering | 10d | 2024-11-22 | 2024-12-08 | A3220 SS+3d, A2420 SS, A2880 SS, A3930 SS | 100% |
| A3240 | Export compressor — fabrication — U-21 Inlet & Metering | 10d | 2024-12-06 | 2024-12-21 | A3230 SS+3d | 100% |
| A3250 | Refrigeration compressor — RFQ & TBE — U-21 Inlet & Metering | 10d | 2024-12-21 | 2025-01-05 | A3240 SS+3d | 100% |
| A3260 | Refrigeration compressor — fabrication — U-21 Inlet & Metering | 16d | 2025-01-05 | 2025-01-27 | A3250 SS+3d | 100% |
| A3270 | String test & FAT — U-21 Inlet & Metering | 28d | 2025-01-20 | 2025-02-27 | A3260 SS+8d | 100% |
| A3280 | Auxiliary skids — fabrication — U-21 Inlet & Metering | 24d | 2025-02-04 | 2025-03-10 | A3270 SS+9d | 100% |
| A3290 | Transport & delivery to site — U-21 Inlet & Metering | 15d | 2025-02-20 | 2025-03-13 | A3280 SS+8d, A4210 SS, A4130 SS | 100% |
| A3300 | Export compressor — RFQ & TBE — U-22 Compression | 11d | 2025-03-07 | 2025-03-24 | A3290 SS+10d, A4170 SS, A4250 SS | 100% |
| A3310 | Export compressor — PO & kick-off — U-22 Compression | 12d | 2025-03-20 | 2025-04-07 | A3300 SS+3d | 100% |
| A3320 | Export compressor — fabrication — U-22 Compression | 17d | 2025-04-09 | 2025-05-04 | A3310 SS+4d, A4350 SS, A2150 SS | 100% |
| A3330 | Refrigeration compressor — RFQ & TBE — U-22 Compression | 15d | 2025-04-26 | 2025-05-18 | A3320 SS+7d | 100% |
| A3340 | Refrigeration compressor — fabrication — U-22 Compression | 27d | 2025-05-13 | 2025-06-19 | A3330 SS+10d, A3050 SS, A4430 SS | 100% |
| A3350 | String test & FAT — U-22 Compression | 22d | 2025-05-21 | 2025-06-22 | A3340 SS+5d, A3620 SS, A2570 SS | 100% |
| A3360 | Auxiliary skids — fabrication — U-22 Compression | 11d | 2025-06-08 | 2025-06-23 | A3350 SS+8d | 100% |
| A3370 | Transport & delivery to site — U-22 Compression | 26d | 2025-06-25 | 2025-07-31 | A3360 SS+9d, A2240 SS, A4800 SS | 100% |
| A3380 | Export compressor — RFQ & TBE — U-23 Dehydration | 21d | 2025-07-08 | 2025-08-06 | A3370 SS+6d | 100% |
| A3390 | Export compressor — PO & kick-off — U-23 Dehydration | 18d | 2025-07-30 | 2025-08-25 | A3380 SS+3d, A2270 SS, A4890 SS | 100% |
| A3400 | Export compressor — fabrication — U-23 Dehydration | 14d | 2025-08-09 | 2025-08-28 | A3390 SS+10d, A4910 SS, A4900 SS | 100% |
| A3410 | Refrigeration compressor — RFQ & TBE — U-23 Dehydration | 25d | 2025-08-16 | 2025-09-19 | A3400 SS+5d | 100% |

| ID | Activity | Duration | Start | Finish | Predecessors | Complete | Remaining |
| --- | --- | --- | --- | --- | --- | --- | --- |
|  | **Bulk Materials (Pipe / Cable)** |  | 2025-01-06 | 2025-12-19 |  |  |  |
| A3420 | Piping bulks — MTO freeze | 24d | 2025-01-06 | 2025-02-09 | A1980 SS+27d, A4050 SS, A2050 SS | 100% |  |
| A3430 | Piping bulks — PO & mill runs | 25d | 2025-01-13 | 2025-02-17 | A3420 SS+4d, A1820 SS, A3260 SS | 100% |  |
| A3440 | Manual valves — PO | 27d | 2025-01-18 | 2025-02-25 | A3430 SS+4d, A1830 SS, A4070 SS | 100% |  |
| A3450 | Special piping items — PO | 12d | 2025-01-25 | 2025-02-11 | A3440 SS+9d | 100% |  |
| A3460 | Structural steel — PO & rolling | 20d | 2025-02-01 | 2025-03-02 | A3450 SS+8d, A4100 SS | 100% |  |
| A3470 | Cable & tray — PO | 23d | 2025-02-05 | 2025-03-10 | A3460 SS+10d, A1860 SS, A4110 SS | 100% |  |
| A3480 | Instrument bulks — PO | 12d | 2025-02-12 | 2025-02-28 | A3470 SS+3d | 100% |  |
| A3490 | Paint & insulation — PO | 19d | 2025-02-20 | 2025-03-19 | A3480 SS+7d | 100% |  |
| A3500 | Bulk deliveries & laydown | 16d | 2025-03-02 | 2025-03-24 | A3490 SS+10d | 100% |  |
| A3510 | Piping bulks — MTO freeze — U-21 Inlet & Metering | 15d | 2025-03-02 | 2025-03-22 | A3500 SS+3d, A2980 SS, A2970 SS | 100% |  |
| A3520 | Piping bulks — PO & mill runs — U-21 Inlet & Metering | 16d | 2025-03-13 | 2025-04-06 | A3510 SS+7d, A4260 SS, A4170 SS | 100% |  |
| A3530 | Manual valves — PO — U-21 Inlet & Metering | 19d | 2025-03-16 | 2025-04-10 | A3520 SS+3d | 100% |  |
| A3540 | Special piping items — PO — U-21 Inlet & Metering | 18d | 2025-03-24 | 2025-04-17 | A3530 SS+9d, A3310 SS, A2130 SS | 100% |  |
| A3550 | Structural steel — PO & rolling — U-21 Inlet & Metering | 25d | 2025-03-31 | 2025-05-05 | A3540 SS+7d, A4330 SS, A4310 SS | 100% |  |
| A3560 | Cable & tray — PO — U-21 Inlet & Metering | 16d | 2025-04-10 | 2025-05-02 | A3550 SS+3d, A4360 SS, A4350 SS | 100% |  |
| A3570 | Instrument bulks — PO — U-21 Inlet & Metering | 13d | 2025-04-18 | 2025-05-07 | A3560 SS+6d, A3020 SS, A2160 SS | 100% |  |
| A3580 | Paint & insulation — PO — U-21 Inlet & Metering | 11d | 2025-04-20 | 2025-05-05 | A3570 SS+3d | 100% |  |
| A3590 | Bulk deliveries & laydown — U-21 Inlet & Metering | 28d | 2025-04-28 | 2025-06-05 | A3580 SS+3d, A3330 SS, A2550 SS | 100% |  |
| A3600 | Piping bulks — MTO freeze — U-22 Compression | 11d | 2025-05-01 | 2025-05-18 | A3590 SS+10d | 100% |  |
| A3610 | Piping bulks — PO & mill runs — U-22 Compression | 22d | 2025-05-14 | 2025-06-15 | A3600 SS+6d | 100% |  |
| A3620 | Manual valves — PO — U-22 Compression | 24d | 2025-05-20 | 2025-06-23 | A3610 SS+4d | 100% |  |
| A3630 | Special piping items — PO — U-22 Compression | 24d | 2025-05-26 | 2025-06-29 | A3620 SS+4d, A3060 SS | 100% |  |
| A3640 | Structural steel — PO & rolling — U-22 Compression | 12d | 2025-06-03 | 2025-06-19 | A3630 SS+8d, A4520 SS, A2210 SS | 100% |  |
| A3650 | Cable & tray — PO — U-22 Compression | 26d | 2025-06-10 | 2025-07-16 | A3640 SS+5d | 100% |  |
| A3660 | Instrument bulks — PO — U-22 Compression | 24d | 2025-06-16 | 2025-07-19 | A3650 SS+6d, A4780 SS, A4760 SS | 100% |  |
| A3670 | Paint & insulation — PO — U-22 Compression | 27d | 2025-06-24 | 2025-07-31 | A3660 SS+8d, A4800 SS, A4560 SS | 100% |  |
| A3680 | Bulk deliveries & laydown — U-22 Compression | 20d | 2025-06-26 | 2025-07-24 | A3670 SS+6d | 100% |  |
| A3690 | Piping bulks — MTO freeze — U-23 Dehydration | 20d | 2025-07-04 | 2025-08-02 | A3680 SS+9d, A2350, A2600 SS, A4810 SS | 100% |  |
| A3700 | Piping bulks — PO & mill runs — U-23 Dehydration | 13d | 2025-07-08 | 2025-07-25 | A3690 SS+9d, A3100 SS, A4600 SS | 100% |  |
| A3710 | Manual valves — PO — U-23 Dehydration | 14d | 2025-07-14 | 2025-08-02 | A3700 SS+4d, A4630 SS, A4830 SS | 100% |  |
| A3720 | Special piping items — PO — U-23 Dehydration | 25d | 2025-07-23 | 2025-08-27 | A3710 SS+8d, A4850 SS, A4860 SS | 100% |  |
| A3730 | Structural steel — PO & rolling — U-23 Dehydration | 13d | 2025-07-29 | 2025-08-17 | A3720 SS+3d | 100% |  |
| A3740 | Cable & tray — PO — U-23 Dehydration | 24d | 2025-08-04 | 2025-09-07 | A3730 SS+3d, A4670 SS | 100% |  |
| A3750 | Instrument bulks — PO — U-23 Dehydration | 12d | 2025-08-16 | 2025-09-02 | A3740 SS+4d, A4730 SS, A4920 SS | 100% |  |
| A3760 | Paint & insulation — PO — U-23 Dehydration | 18d | 2025-08-19 | 2025-09-13 | A3750 SS+3d, A3410 SS, A4730 SS | 100% |  |
| A3770 | Bulk deliveries & laydown — U-23 Dehydration | 28d | 2025-08-24 | 2025-10-01 | A3760 SS+3d, A4950 SS, A2290 SS | 100% |  |
| A3780 | Piping bulks — MTO freeze — U-24 Fractionation | 13d | 2025-09-02 | 2025-09-19 | A3770 SS+5d | 100% |  |
| A3790 | Piping bulks — PO & mill runs — U-24 Fractionation | 23d | 2025-09-11 | 2025-10-14 | A3780 SS+7d |  | 23d |
| A3800 | Manual valves — PO — U-24 Fractionation | 18d | 2025-09-17 | 2025-10-13 | A3790 SS+3d, A2330 SS, A5440 SS |  | 18d |
| A3810 | Special piping items — PO — U-24 Fractionation | 24d | 2025-09-20 | 2025-10-23 | A3800 SS+9d, A5460 SS, A5910 SS |  | 24d |
| A3820 | Structural steel — PO & rolling — U-24 Fractionation | 21d | 2025-10-01 | 2025-10-30 | A3810 SS+10d |  |  |
| A3830 | Cable & tray — PO — U-24 Fractionation | 13d | 2025-10-07 | 2025-10-24 | A3820 SS+9d |  |  |
| A3840 | Instrument bulks — PO — U-24 Fractionation | 27d | 2025-10-08 | 2025-11-14 | A3830 SS+10d, A5980 SS, A5970 SS |  |  |
| A3850 | Paint & insulation — PO — U-24 Fractionation | 15d | 2025-10-15 | 2025-11-05 | A3840 SS+3d, A5090 SS, A5990 SS |  |  |
| A3860 | Bulk deliveries & laydown — U-24 Fractionation | 20d | 2025-10-25 | 2025-11-23 | A3850 SS+10d |  |  |
| A3870 | Piping bulks — MTO freeze — U-25 Utilities | 19d | 2025-10-26 | 2025-11-20 | A3860 SS+4d, A6020 SS |  |  |
| A3880 | Piping bulks — PO & mill runs — U-25 Utilities | 26d | 2025-11-05 | 2025-12-11 | A3870 SS+10d |  |  |
| A3890 | Manual valves — PO — U-25 Utilities | 26d | 2025-11-13 | 2025-12-19 | A3880 SS+7d |  |  |
| A3910 | Structural steel — PO & rolling — U-25 Utilities | 25d | 2025-11-16 | 2025-12-19 | A3900 SS+9d |  |  |
| A3900 | Special piping items — PO — U-25 Utilities | 13d | 2025-11-19 | 2025-12-08 | A3890 SS+10d |  |  |

| ID | Activity | Duration | Start | Finish | Predecessors | Complete |
| --- | --- | --- | --- | --- | --- | --- |
|  | **Long-Lead Eqpt — Vessels & HX** |  | 2024-06-03 | 2025-08-29 |  |  |
| A2720 | Inlet separator — RFQ & TBE | 24d | 2024-06-03 | 2024-07-05 | A1000 SS+103d, A1280 SS, A1210 SS, A1270 | 100% |
| A2730 | Inlet separator — PO & kick-off | 15d | 2024-06-16 | 2024-07-07 | A2720 SS+4d | 100% |
| A2740 | Inlet separator — fabrication | 13d | 2024-06-22 | 2024-07-10 | A2730 SS+10d | 100% |
| A2750 | Fractionation columns — RFQ & TBE | 14d | 2024-07-08 | 2024-07-27 | A2740 SS+7d | 100% |
| A2760 | Fractionation columns — PO & kick-off | 18d | 2024-07-11 | 2024-08-06 | A2750 SS+4d, A1560 SS, A1550 SS, A1240 | 100% |
| A2770 | Fractionation columns — fabrication | 25d | 2024-07-27 | 2024-08-31 | A2760 SS+9d | 100% |
| A2780 | Shell & tube exchangers — RFQ & TBE | 11d | 2024-08-07 | 2024-08-22 | A2770 SS+4d | 100% |
| A2790 | Shell & tube exchangers — fabrication | 26d | 2024-08-11 | 2024-09-16 | A2780 SS+9d | 100% |
| A2800 | Air coolers — RFQ & TBE | 27d | 2024-08-25 | 2024-10-01 | A2790 SS+9d | 100% |
| A2810 | Air coolers — fabrication | 15d | 2024-09-06 | 2024-09-29 | A2800 SS+10d, A1440 SS, A1920 SS, A1630 SS | 100% |
| A2820 | Inspection & FAT | 25d | 2024-09-11 | 2024-10-16 | A2810 SS+9d | 100% |
| A2830 | Transport & delivery to site | 25d | 2024-09-28 | 2024-11-01 | A2820 SS+7d | 100% |
| A2840 | Inlet separator — RFQ & TBE — U-21 Inlet & Metering | 21d | 2024-10-06 | 2024-11-04 | A2830 SS+8d | 100% |
| A2850 | Inlet separator — PO & kick-off — U-21 Inlet & Metering | 23d | 2024-10-18 | 2024-11-20 | A2840 SS+10d, A1700 SS, A2390 SS, A1490 SS | 100% |
| A2860 | Inlet separator — fabrication — U-21 Inlet & Metering | 24d | 2024-10-29 | 2024-12-02 | A2850 SS+10d | 100% |
| A2870 | Fractionation columns — RFQ & TBE — U-21 Inlet & Metering | 15d | 2024-11-10 | 2024-11-29 | A2860 SS+8d, A2410 SS, A1990 SS, A3220 SS | 100% |
| A2880 | Fractionation columns — PO & kick-off — U-21 Inlet & Metering | 27d | 2024-11-16 | 2024-12-24 | A2870 SS+7d | 100% |
| A2890 | Fractionation columns — fabrication — U-21 Inlet & Metering | 13d | 2024-12-01 | 2024-12-18 | A2880 SS+5d | 100% |
| A2900 | Shell & tube exchangers — RFQ & TBE — U-21 Inlet & Metering | 16d | 2024-12-12 | 2025-01-03 | A2890 SS+8d | 100% |
| A2910 | Shell & tube exchangers — fabrication — U-21 Inlet & Metering | 14d | 2024-12-14 | 2025-01-02 | A2900 SS+9d, A1780 SS, A3240 SS | 100% |
| A2920 | Air coolers — RFQ & TBE — U-21 Inlet & Metering | 27d | 2024-12-28 | 2025-02-04 | A2910 SS+7d, A1800 SS, A3250 SS | 100% |
| A2930 | Air coolers — fabrication — U-21 Inlet & Metering | 19d | 2025-01-05 | 2025-01-30 | A2920 SS+5d, A2050 SS, A4040 SS | 100% |
| A2940 | Inspection & FAT — U-21 Inlet & Metering | 25d | 2025-01-19 | 2025-02-21 | A2930 SS+4d, A4080 SS, A1830 SS | 100% |
| A2950 | Transport & delivery to site — U-21 Inlet & Metering | 14d | 2025-01-28 | 2025-02-17 | A2940 SS+4d, A3450 SS, A3270 SS | 100% |
| A2960 | Inlet separator — RFQ & TBE — U-22 Compression | 21d | 2025-02-12 | 2025-03-13 | A2950 SS+7d, A4190 SS, A4120 SS | 100% |
| A2970 | Inlet separator — PO & kick-off — U-22 Compression | 20d | 2025-02-22 | 2025-03-21 | A2960 SS+10d | 100% |
| A2980 | Inlet separator — fabrication — U-22 Compression | 13d | 2025-02-25 | 2025-03-15 | A2970 SS+8d | 100% |
| A2990 | Fractionation columns — RFQ & TBE — U-22 Compression | 23d | 2025-03-14 | 2025-04-16 | A2980 SS+7d | 100% |
| A3000 | Fractionation columns — PO & kick-off — U-22 Compression | 20d | 2025-03-22 | 2025-04-19 | A2990 SS+7d | 100% |
| A3010 | Fractionation columns — fabrication — U-22 Compression | 16d | 2025-04-05 | 2025-04-28 | A3000 SS+7d, A2150 SS, A4320 SS | 100% |
| A3020 | Shell & tube exchangers — RFQ & TBE — U-22 Compression | 19d | 2025-04-14 | 2025-05-09 | A3010 SS+5d | 100% |
| A3030 | Shell & tube exchangers — fabrication — U-22 Compression | 24d | 2025-04-21 | 2025-05-23 | A3020 SS+6d, A4390 SS | 100% |
| A3040 | Air coolers — RFQ & TBE — U-22 Compression | 14d | 2025-05-01 | 2025-05-21 | A3030 SS+6d, A2170 SS, A3330 SS | 100% |
| A3050 | Air coolers — fabrication — U-22 Compression | 17d | 2025-05-09 | 2025-06-03 | A3040 SS+3d | 100% |
| A3060 | Inspection & FAT — U-22 Compression | 22d | 2025-05-21 | 2025-06-22 | A3050 SS+10d | 100% |
| A3070 | Transport & delivery to site — U-22 Compression | 27d | 2025-06-03 | 2025-07-10 | A3060 SS+3d | 100% |
| A3080 | Inlet separator — RFQ & TBE — U-23 Dehydration | 20d | 2025-06-16 | 2025-07-14 | A3070 SS+5d | 100% |
| A3090 | Inlet separator — PO & kick-off — U-23 Dehydration | 24d | 2025-06-23 | 2025-07-26 | A3080 SS+5d, A4560 SS, A4790 SS | 100% |
| A3100 | Inlet separator — fabrication — U-23 Dehydration | 25d | 2025-07-05 | 2025-08-10 | A3090 SS+6d | 100% |
| A3110 | Fractionation columns — RFQ & TBE — U-23 Dehydration | 23d | 2025-07-15 | 2025-08-15 | A3100 SS+7d, A2610 SS, A4630 SS | 100% |
| A3120 | Fractionation columns — PO & kick-off — U-23 Dehydration | 19d | 2025-07-28 | 2025-08-24 | A3110 SS+4d, A4890 SS, A4650 SS | 100% |
| A3130 | Fractionation columns — fabrication — U-23 Dehydration | 15d | 2025-08-09 | 2025-08-29 | A3120 SS+10d | 100% |
